# CANTERAS - HUARMEY - LB01

Schedule from Primavera P6, 2022-10-11 to 2024-10-23, data date 2022-10-11, costs in PEN.
ESTE PROYECTO PERTENECE A LA EXPLOTACIÓN DE LA CANTERA / CASMA.

## Calendars

- Calendario Huarmey Project: Mon-Sat 02:00-22:00; Sun off. Exceptions (off unless hours are given): 2022-11-01, 2022-12-08 to 2022-12-09, 2022-12-25, 2023-01-01, 2023-04-06 to 2023-04-07, 2023-05-01, 2023-06-29, 2023-07-28 to 2023-07-29, 2023-08-30, 2023-11-01, 2023-12-08 to 2023-12-09, 2023-12-25, 2024-01-01, 2024-03-28 to 2024-03-29.

## Resources

| Resource | Group | Rate |
| --- | --- | --- |
| COSTOS HUARMEY | labor | 1 |

## Schedule

| ID | WBS | Activity | Type | Duration | Start | Finish | Predecessors | Total float | Free float | Resources | Cost |
| --- | --- | --- | --- | --- | --- | --- | --- | --- | --- | --- | --- |
|  | 1 | **HITOS PRINCIPALES** |  |  | 2022-10-11 | 2024-10-23 |  |  |  |  |  |
| HT.0020 |  | Inicio de Proyecto | milestone | 0d | 2022-10-11 | 2022-10-11 |  | 0d |  |  |  |
| HT.0010 |  | Fin de Proyecto | milestone | 0d | 2024-10-23 | 2024-10-23 | HU.0150 FF, VA.0070 FF, VA.0010 FF, CO.0200 FF, QM.0190 FF | 0d |  |  |  |
|  | 2 | **OBRAS PROVISIONALES** |  |  | 2022-10-12 | 2023-01-12 |  |  |  |  |  |
|  | 1 | **TRAMITES, GESTIÓN Y OBTENCIÓN DE PERMISOS** |  |  | 2022-10-12 | 2023-01-12 |  |  |  |  |  |
| OP.0030 |  | Tramite, gestión y obtención de permisos para almacenamiento y uso de Polvorín |  | 29d | 2022-10-12 | 2022-11-15 | HT.0020 SS+1d | 0d |  | COSTOS HUARMEY [20716.7 h] | 20,716.71 |
| OP.0010 |  | Tramite, gestión y obtención de permisos para uso y adquisición de explosivos |  | 63d | 2022-10-14 | 2022-12-29 | OP.0030 SS+2d | 236d | 39d | COSTOS HUARMEY [15576.5 h] | 15,576.47 |
| OP.0020 |  | Tramite, gestión y obtención de permisos para manipulación de explosivos |  | 36d | 2022-11-16 | 2022-12-29 | OP.0030 | 330d | 0d | COSTOS HUARMEY [15576.5 h] | 15,576.47 |
| OP.0040 |  | Trámite, gestión y obtención de permisos para explotación de canteras |  | 9d | 2022-11-16 | 2022-11-25 | OP.0030 | 172d | 28d | COSTOS HUARMEY [15576.5 h] | 15,576.47 |
| OP.0050 |  | Instalación de campamento, patio taller y oficinas |  | 36d | 2022-11-16 | 2022-12-29 | OP.0030 | 236d | 39d | COSTOS HUARMEY [1936717 h] | 1,936,717.04 |
| OP.0060 |  | Construcción e implementación de polvorín |  | 48d | 2022-11-16 | 2023-01-12 | OP.0030 | 537d | 202d | COSTOS HUARMEY [443328 h] | 443,328.37 |
|  | 3 | **HITOS DE CONSTRUCCIÓN** |  |  | 2022-11-16 | 2023-09-16 |  |  |  |  |  |
| HC.0010 |  | Aprobación de ingreso a cantera - Huarmey Parte Alta | milestone | 0d | 2022-11-16 | 2022-11-16 | OP.0030 | 0d |  |  |  |
| HC.0050 |  | Aprobación de ingreso a cantera - San Damian | milestone | 0d | 2023-01-25 | 2023-01-25 | OP.0020 FS+22d | 330d | 0d |  |  |
| HC.0020 |  | Aprobación de ingreso a cantera - Huarmey Parte Baja | milestone | 0d | 2023-09-14 | 2023-09-14 | OP.0020, OP.0060, QA.0040 SS | 335d | 189d |  |  |
| HC.0040 |  | Aprobación de ingreso a cantera - Quebrada Aija | milestone | 0d | 2023-09-14 | 2023-09-14 | QA.0040 SS | 335d | 189d |  |  |
| HC.0030 |  | Aprobación de ingreso a cantera - Quebrada Malvas | milestone | 0d | 2023-09-16 | 2023-09-16 | A2080 SS | 338d | 187d |  |  |
|  | 4 | **HUARMEY (PARTE ALTA)** |  |  | 2022-11-24 | 2024-10-23 |  |  |  |  |  |
|  | 1 | **OBRAS PRELIMINARES** |  |  | 2022-11-24 | 2024-10-23 |  |  |  |  |  |
| HU.0010 |  | Movilización y desmovilización de maquinaria | level of effort | 584d | 2022-11-24 | 2024-10-23 | T1.0010 SS | 0d |  | COSTOS HUARMEY [826424 h] | 826,423.59 |
| HU.0020 |  | Ensayos de Roca (determinado por el proveedor) | level of effort | 402d | 2022-12-31 | 2024-04-29 | T1.0020 SS | 151d | 0d | COSTOS HUARMEY [133210 h] | 133,210.38 |
|  | 3 | **TAYCA 1** |  |  | 2022-11-24 | 2024-10-19 |  |  |  |  |  |
|  | 1 | **TAYCA 1** |  |  | 2022-11-24 | 2024-10-14 |  |  |  |  |  |
|  | 1 | **TRABAJOS DE CANTERA** |  |  | 2022-11-24 | 2024-04-29 |  |  |  |  |  |
| T1.0010 |  | Habilitación de caminos de accesos |  | 26d | 2022-11-24 | 2022-12-26 | HC.0010 SS+7d | 0d |  | COSTOS HUARMEY [751622 h] | 751,621.89 |
| T1.0020 |  | Extracción de roca en cantera (con explosivos) Fase 1 |  | 38d | 2022-12-31 | 2023-02-13 | T1.0010 FS+4d, OP.0040 | 144d | 0d | COSTOS HUARMEY [5743704 h] | 5,743,703.74 |
| T1.0030 |  | Extracción de roca en cantera (con explosivos) Fase 2 |  | 38d | 2023-02-14 | 2023-03-29 | T1.0020, OP.0010, OP.0040, OP.0050, VA.0040, T1.0010, OP.0030 | 197d | 15d | COSTOS HUARMEY [5743704 h] | 5,743,703.74 |
| T1.0040 |  | Extracción de roca en cantera (con explosivos) Fase 3 |  | 38d | 2023-04-19 | 2023-06-02 | T1.0030, T1.0260, T1.0140, T1.0270, T1.0080, OP.0030 | 235d | 53d | COSTOS HUARMEY [5743704 h] | 5,743,703.74 |
| T1.0050 |  | Extracción de roca en cantera (con explosivos) Fase 4 |  | 38d | 2023-08-08 | 2023-09-21 | T1.0040, T1.0150, T1.0090, T1.0210, T1.0030, T1.0090 FF, OP.0030 | 235d | 0d | COSTOS HUARMEY [5743704 h] | 5,743,703.74 |
| T1.0060 |  | Extracción de roca en cantera (con explosivos) Fase 5 |  | 38d | 2023-09-22 | 2023-11-06 | T1.0050, OP.0030 | 252d | 106d | COSTOS HUARMEY [5743704 h] | 5,743,703.74 |
| T1.0070 |  | Extracción de roca en cantera (con explosivos) Fase 6 |  | 38d | 2024-03-14 | 2024-04-29 | T1.0060, VA.0050, VA.0060, T1.0110, HC.0020 SF, HC.0040 SF, OP.0030 | 146d | 0d | COSTOS HUARMEY [5743704 h] | 5,743,703.74 |

| ID | WBS | Activity | Duration | Start | Finish | Predecessors | Total float | Free float | Resources | Cost |
| --- | --- | --- | --- | --- | --- | --- | --- | --- | --- | --- |
|  | SELECCION DE ROCA | **SELECCION DE ROCA** |  | 2022-12-31 | 2024-10-14 |  |  |  |  |  |
| T1.0080 |  | Selección y acopio de roca (de acuerdo al diseño y tipo) Fase 1 | 91d | 2022-12-31 | 2023-04-18 | T1.0010 FS+4d | 0d |  | COSTOS HUARMEY [4405690 h] | 4,405,690.12 |
| T1.0140 |  | Transporte de material interno para acopio =1km (incluye carguío) Fase 1 | 46d | 2022-12-31 | 2023-02-22 | T1.0080 SS | 136d | 45d | COSTOS HUARMEY [1335102 h] | 1,335,101.73 |
| T1.0090 |  | Selección y acopio de roca (de acuerdo al diseño y tipo) Fase 2 | 91d | 2023-04-19 | 2023-08-07 | T1.0080, T1.0010, OP.0030 | 0d |  | COSTOS HUARMEY [4405690 h] | 4,405,690.12 |
| T1.0150 |  | Transporte de material interno para acopio =1km (incluye carguío) Fase 2 | 46d | 2023-04-19 | 2023-06-12 | T1.0140, T1.0080, T1.0200 | 136d | 45d | COSTOS HUARMEY [1335102 h] | 1,335,101.73 |
| T1.0100 |  | Selección y acopio de roca (de acuerdo al diseño y tipo) Fase 3 | 91d | 2023-08-08 | 2023-11-23 | T1.0090, T1.0140, T1.0080, T1.0020, T1.0010, OP.0030 | 0d |  | COSTOS HUARMEY [4405690 h] | 4,405,690.12 |
| T1.0160 |  | Transporte de material interno para acopio =1km (incluye carguío) Fase 3 | 37d | 2023-08-08 | 2023-09-20 | T1.0150, T1.0090 | 205d | 0d | COSTOS HUARMEY [1335102 h] | 1,335,101.73 |
| T1.0110 |  | Selección y acopio de roca (de acuerdo al diseño y tipo) Fase 4 | 91d | 2023-11-24 | 2024-03-13 | T1.0100, T1.0150, T1.0020, T1.0010, T1.0030, OP.0030 | 0d |  | COSTOS HUARMEY [4405690 h] | 4,405,690.12 |
| T1.0170 |  | Transporte de material interno para acopio =1km (incluye carguío) Fase 4 | 31d | 2023-11-24 | 2024-01-03 | T1.0160, T1.0100, T1.0220 | 151d | 0d | COSTOS HUARMEY [1335102 h] | 1,335,101.73 |
| T1.0180 |  | Transporte de material interno para acopio =1km (incluye carguío) Fase 5 | 31d | 2024-01-04 | 2024-02-08 | T1.0170 | 182d | 0d | COSTOS HUARMEY [1335102 h] | 1,335,101.73 |
| T1.0190 |  | Transporte de material interno para acopio =1km (incluye carguío) Fase 6 | 31d | 2024-02-09 | 2024-03-15 | T1.0180 | 182d | 180d | COSTOS HUARMEY [1335102 h] | 1,335,101.73 |
| T1.0120 |  | Selección y acopio de roca (de acuerdo al diseño y tipo) Fase 5 | 91d | 2024-03-14 | 2024-06-29 | T1.0110, T1.0100, T1.0020, T1.0010, T1.0030, T1.0040, OP.0030 | 0d |  | COSTOS HUARMEY [4405690 h] | 4,405,690.12 |
| T1.0130 |  | Selección y acopio de roca (de acuerdo al diseño y tipo) Fase 6 | 91d | 2024-07-01 | 2024-10-14 | T1.0120, T1.0170, T1.0020, T1.0030, T1.0050, OP.0030 | 0d |  | COSTOS HUARMEY [4405690 h] | 4,405,690.12 |
|  | 2 | **ELLIMINACIÓN DE ROCA (DESPERDICIO)** |  | 2022-12-31 | 2024-10-14 |  |  |  |  |  |
| T1.0200 |  | Eliminación de material excedente = 1km (incluye carguío) Fase 1 | 47d | 2022-12-31 | 2023-02-23 | T1.0010 FS+4d | 180d | 0d | COSTOS HUARMEY [634637 h] | 634,636.8 |
| T1.0260 |  | Eliminación de material excedente > 1km Fase 1 | 2d | 2022-12-31 | 2023-01-02 | T1.0010 FS+4d | 322d | 0d | COSTOS HUARMEY [865802 h] | 865,802.07 |
| T1.0270 |  | Eliminación de material excedente > 1km Fase 2 | 2d | 2023-01-03 | 2023-01-04 | T1.0260 | 322d | 0d | COSTOS HUARMEY [865802 h] | 865,802.07 |
| T1.0280 |  | Eliminación de material excedente > 1km Fase 3 | 2d | 2023-01-05 | 2023-01-06 | T1.0270 | 531d | 0d | COSTOS HUARMEY [865802 h] | 865,802.07 |
| T1.0290 |  | Eliminación de material excedente > 1km Fase 4 | 3d | 2023-01-07 | 2023-01-10 | T1.0280 | 531d | 132d | COSTOS HUARMEY [865802 h] | 865,802.07 |
| T1.0210 |  | Eliminación de material excedente = 1km (incluye carguío) Fase 2 | 47d | 2023-02-24 | 2023-04-21 | T1.0200 | 266d | 0d | COSTOS HUARMEY [634637 h] | 634,636.8 |
| T1.0220 |  | Eliminación de material excedente = 1km (incluye carguío) Fase 3 | 47d | 2023-04-22 | 2023-06-16 | T1.0210 | 266d | 0d | COSTOS HUARMEY [634637 h] | 634,636.8 |
| T1.0230 |  | Eliminación de material excedente = 1km (incluye carguío) Fase 4 | 47d | 2023-06-17 | 2023-08-14 | T1.0220 | 266d | 31d | COSTOS HUARMEY [634637 h] | 634,636.8 |
| T1.0300 |  | Eliminación de material excedente > 1km Fase 5 | 3d | 2023-06-17 | 2023-06-20 | T1.0290, T1.0220 | 399d | 258d | COSTOS HUARMEY [865802 h] | 865,802.07 |
| T1.0240 |  | Eliminación de material excedente = 1km (incluye carguío) Fase 5 | 47d | 2023-09-21 | 2023-11-15 | T1.0230, T1.0160 | 235d | 89d | COSTOS HUARMEY [634637 h] | 634,636.8 |
| T1.0250 |  | Eliminación de material excedente = 1km (incluye carguío) Fase 6 | 47d | 2024-03-04 | 2024-04-29 | T1.0240, T1.0070 FF | 146d | 144d | COSTOS HUARMEY [634637 h] | 634,636.8 |
| T1.0310 |  | Eliminación de material excedente > 1km Fase 6 | 3d | 2024-10-11 | 2024-10-14 | T1.0300, T1.0130 FF, T1.0110, T1.0080, T1.0090, T1.0110 FF | 0d |  | COSTOS HUARMEY [865802 h] | 865,802.07 |

| ID | WBS | Activity | Duration | Start | Finish | Predecessors | Total float | Free float | Resources | Cost |
| --- | --- | --- | --- | --- | --- | --- | --- | --- | --- | --- |
|  | 7 | **TRABAJOS DE CIERRE** |  | 2022-12-31 | 2024-10-19 |  |  |  |  |  |
| HU.0030 |  | Conformación de DME Fase 1 | 46d | 2022-12-31 | 2023-02-22 | T1.0010 FS+4d | 270d | 0d | COSTOS HUARMEY [342632 h] | 342,632.43 |
| HU.0040 |  | Conformación de DME Fase 2 | 46d | 2023-02-23 | 2023-04-19 | HU.0030 | 270d | 0d | COSTOS HUARMEY [342632 h] | 342,632.43 |
| HU.0050 |  | Conformación de DME Fase 3 | 46d | 2023-04-20 | 2023-06-13 | HU.0040 | 270d | 0d | COSTOS HUARMEY [342632 h] | 342,632.43 |
| HU.0060 |  | Conformación de DME Fase 4 | 46d | 2023-06-14 | 2023-08-09 | HU.0050 | 270d | 0d | COSTOS HUARMEY [342632 h] | 342,632.43 |
| HU.0070 |  | Conformación de DME Fase 5 | 46d | 2023-08-10 | 2023-10-03 | HU.0060 | 270d | 0d | COSTOS HUARMEY [342632 h] | 342,632.43 |
| HU.0080 |  | Conformación de DME Fase 6 | 46d | 2024-08-22 | 2024-10-14 | HU.0070, T1.0310 FF | 0d |  | COSTOS HUARMEY [342632 h] | 342,632.43 |
| HU.0090 |  | Limpieza y nivelación del terreno | 5d | 2024-10-15 | 2024-10-19 | HU.0030, T1.0310, HU.0080, T1.0190, T1.0250 | 2d | 0d | COSTOS HUARMEY [8948.08 h] | 8,948.08 |
|  | 5 | **TAYCA 2** |  | 2023-10-04 | 2024-10-23 |  |  |  |  |  |
|  | 0 | **TAYCA 2** |  | 2023-10-04 | 2024-10-23 |  |  |  |  |  |
|  | 1 | **TRABAJOS DE CANTERA** |  | 2023-10-04 | 2024-04-30 |  |  |  |  |  |
| T2.0010 |  | Habilitación de caminos de accesos a Cantera | 0d | 2023-10-04 | 2023-10-04 | HU.0070 | 323d | 172d | COSTOS HUARMEY |  |
| T2.0020 |  | Extracción de roca en cantera (con explosivos) Fase 1 | 0d | 2024-04-30 | 2024-04-30 | T2.0010, T1.0070, CO.0020, T1.0180, T1.0170, T1.0240, T1.0230, T1.0300 | 151d | 0d | COSTOS HUARMEY |  |
| T2.0030 |  | Extracción de roca en cantera (con explosivos) Fase 2 | 0d | 2024-04-30 | 2024-04-30 | T2.0020 | 151d | 0d | COSTOS HUARMEY |  |
| T2.0040 |  | Extracción de roca en cantera (con explosivos) Fase 3 | 0d | 2024-04-30 | 2024-04-30 | T2.0030, HC.0030 SF | 151d | 0d | COSTOS HUARMEY |  |
| T2.0050 |  | Extracción de roca en cantera (con explosivos) Fase 4 | 0d | 2024-04-30 | 2024-04-30 | T2.0040 | 151d | 0d | COSTOS HUARMEY |  |
| T2.0060 |  | Extracción de roca en cantera (con explosivos) Fase 5 | 0d | 2024-04-30 | 2024-04-30 | T2.0050, HU.0020 FF | 151d |  | COSTOS HUARMEY |  |
|  | 2 | **SELECCIÓN DE ROCA** |  | 2024-04-30 | 2024-10-23 |  |  |  |  |  |
| T2.0070 |  | Selección y acopio de roca (de acuerdo al diseño y tipo) Fase 1 | 0d | 2024-04-30 | 2024-04-30 | T1.0070 | 151d | 149d | COSTOS HUARMEY |  |
| T2.0120 |  | Transporte de material interno para acopio =1km (incluye carguío) Fase 1 | 0d | 2024-04-30 | 2024-04-30 | T2.0020 SS, CO.0060, CO.0100, SD.0110 | 151d | 144d | COSTOS HUARMEY |  |
| T2.0130 |  | Transporte de material interno para acopio =1km (incluye carguío) Fase 2 | 0d | 2024-10-15 | 2024-10-15 | T2.0120, HU.0080 | 7d | 0d | COSTOS HUARMEY |  |
| T2.0140 |  | Transporte de material interno para acopio =1km (incluye carguío) Fase 3 | 0d | 2024-10-15 | 2024-10-15 | T2.0130, T2.0120, T2.0020, T1.0310, HU.0080 | 7d | 6d | COSTOS HUARMEY |  |
| T2.0080 |  | Selección y acopio de roca (de acuerdo al diseño y tipo) Fase 2 | 0d | 2024-10-21 | 2024-10-21 | T2.0070, VA.0030, HU.0090, CO.0080, CO.0090, CO.0120, CO.0130, T1.0120, T1.0130, T1.0250, T1.0310, CO.0030, CO.0050, CO.0070, CO.0110 | 2d | 0d | COSTOS HUARMEY |  |
| T2.0090 |  | Selección y acopio de roca (de acuerdo al diseño y tipo) Fase 3 | 0d | 2024-10-21 | 2024-10-21 | T2.0080, T1.0190, CO.0140, CO.0135 | 2d | 0d | COSTOS HUARMEY |  |
| T2.0100 |  | Selección y acopio de roca (de acuerdo al diseño y tipo) Fase 4 | 0d | 2024-10-21 | 2024-10-21 | T2.0090, CO.0150, CO.0160, CO.0170, CO.0180, CO.0190 | 2d | 0d | COSTOS HUARMEY |  |
| T2.0110 |  | Selección y acopio de roca (de acuerdo al diseño y tipo) Fase 5 | 0d | 2024-10-21 | 2024-10-21 | T2.0100 | 2d |  | COSTOS HUARMEY |  |
| T2.0150 |  | Transporte de material interno para acopio =1km (incluye carguío) Fase 4 | 0d | 2024-10-22 | 2024-10-22 | T2.0140, T2.0220, HU.0100, T2.0020, T1.0310, HU.0080 | 1d |  | COSTOS HUARMEY |  |
| T2.0160 |  | Transporte de material interno para acopio =1km (incluye carguío) Fase 5 | 0d | 2024-10-23 | 2024-10-23 | T2.0150, T2.0140, HU.0120 | 1d |  | COSTOS HUARMEY |  |

| ID | WBS | Activity | Type | Duration | Start | Finish | Predecessors | Total float | Free float | Resources | Cost |
| --- | --- | --- | --- | --- | --- | --- | --- | --- | --- | --- | --- |
|  | 3 | **ELIMINACIÓN DE ROCA (DESPERDICIO)** |  |  | 2024-10-15 | 2024-10-21 |  |  |  |  |  |
| T2.0170 |  | Eliminación de material excedente = 1km (incluye carguío) Fase 1 |  | 0d | 2024-10-15 | 2024-10-15 | HU.0080 | 7d | 0d | COSTOS HUARMEY |  |
| T2.0180 |  | Eliminación de material excedente = 1km (incluye carguío) Fase 2 |  | 0d | 2024-10-15 | 2024-10-15 | T2.0170, T2.0120 | 7d | 5d | COSTOS HUARMEY |  |
| T2.0220 |  | Eliminación de material excedente > 1km Fase 1 |  | 0d | 2024-10-15 | 2024-10-15 | HU.0080 | 0d |  | COSTOS HUARMEY |  |
| T2.0230 |  | Eliminación de material excedente > 1km Fase 2 |  | 0d | 2024-10-15 | 2024-10-15 | T2.0220 | 7d | 0d | COSTOS HUARMEY |  |
| T2.0240 |  | Eliminación de material excedente > 1km Fase 3 |  | 0d | 2024-10-15 | 2024-10-15 | T2.0230 | 7d | 0d | COSTOS HUARMEY |  |
| T2.0250 |  | Eliminación de material excedente > 1km Fase 4 |  | 0d | 2024-10-15 | 2024-10-15 | T2.0240 | 7d | 0d | COSTOS HUARMEY |  |
| T2.0260 |  | Eliminación de material excedente > 1km Fase 5 |  | 0d | 2024-10-15 | 2024-10-15 | T2.0250 | 7d |  | COSTOS HUARMEY |  |
| T2.0190 |  | Eliminación de material excedente = 1km (incluye carguío) Fase 3 |  | 0d | 2024-10-21 | 2024-10-21 | T2.0180, HU.0090, T2.0120 | 2d | 0d | COSTOS HUARMEY |  |
| T2.0200 |  | Eliminación de material excedente = 1km (incluye carguío) Fase 4 |  | 0d | 2024-10-21 | 2024-10-21 | T2.0190, T2.0120 | 2d | 0d | COSTOS HUARMEY |  |
| T2.0210 |  | Eliminación de material excedente = 1km (incluye carguío) Fase 5 |  | 0d | 2024-10-21 | 2024-10-21 | T2.0200 | 2d |  | COSTOS HUARMEY |  |
|  | 6 | **TRABAJOS DE CIERRE** |  |  | 2024-10-22 | 2024-10-23 |  |  |  |  |  |
| HU.0100 |  | Conformación de DME Fase 1 |  | 0d | 2024-10-22 | 2024-10-22 | T2.0220 SS+6d | 0d |  | COSTOS HUARMEY |  |
| HU.0110 |  | Conformación de DME Fase 2 |  | 0d | 2024-10-23 | 2024-10-23 | HU.0100 FS+1d, T2.0220, T2.0120, T2.0020 | 0d |  | COSTOS HUARMEY |  |
| HU.0120 |  | Conformación de DME Fase 3 |  | 0d | 2024-10-23 | 2024-10-23 | HU.0110, HU.0100, T2.0130, T2.0230, T2.0120, T2.0020 | 0d |  | COSTOS HUARMEY |  |
| HU.0130 |  | Conformación de DME Fase 4 |  | 0d | 2024-10-23 | 2024-10-23 | HU.0120, HU.0110, T2.0140, T2.0230, T2.0120, T2.0020 | 0d |  | COSTOS HUARMEY |  |
| HU.0140 |  | Conformación de DME Fase 5 |  | 0d | 2024-10-23 | 2024-10-23 | HU.0130, T2.0150, T2.0230, T2.0120, T2.0140, T2.0020 | 0d |  | COSTOS HUARMEY |  |
| HU.0150 |  | Limpieza y nivelación del terreno |  | 1d | 2024-10-23 | 2024-10-23 | T2.0210, HU.0140, HU.0160 FF, HU.0170 FF, HU.0010 FF, T2.0110, T2.0260, T2.0060, T2.0160 FF, T2.0130, T2.0140, T2.0150, HU.0100, HU.0110, HU.0120 | 0d |  | COSTOS HUARMEY [6559.18 h] | 6,559.18 |
|  | 7 | **SEGURIDAD, SALUD Y MEDIO AMBIENTE** |  |  | 2022-11-24 | 2024-10-23 |  |  |  |  |  |
| HU.0160 |  | Mitigación de impacto ambiental | level of effort | 584d | 2022-11-24 | 2024-10-23 | T1.0010 SS | 0d |  | COSTOS HUARMEY |  |
|  | 8 | **CONTROL DE TOPOGRAFÍA** |  |  | 2022-11-24 | 2024-10-23 |  |  |  |  |  |
| HU.0170 |  | Control topográfico de los trabajos | level of effort | 584d | 2022-11-24 | 2024-10-23 | T1.0010 SS | 0d |  | COSTOS HUARMEY [833471 h] | 833,471.49 |
|  | 5 | **HUARMEY (PARTE BAJA)** |  |  | 2023-05-02 | 2023-05-05 |  |  |  |  |  |
|  | 1 | **OBRAS PRELIMINARES** |  |  | 2023-05-02 | 2023-05-04 |  |  |  |  |  |
| HUB.0010 |  | Movilización y desmovilización de maquinaria | level of effort | 3d | 2023-05-02 | 2023-05-04 | CO.0010 SS | 450d | 0d | COSTOS HUARMEY [73196.4 h] | 73,196.43 |
| HUB.0020 |  | Ensayos de roca (determinado por el proveedor) | level of effort | 3d | 2023-05-02 | 2023-05-04 | CO.0020 SS | 449d | 0d | COSTOS HUARMEY [11798.5 h] | 11,798.46 |

| ID | WBS | Activity | Duration | Start | Finish | Predecessors | Total float | Free float | Resources |
| --- | --- | --- | --- | --- | --- | --- | --- | --- | --- |
|  | 3 | **CONGÓN 2** |  | 2023-05-02 | 2023-05-05 |  |  |  |  |
|  | 1 | **TRABAJOS DE CANTERA** |  | 2023-05-02 | 2023-05-02 |  |  |  |  |
| CO.0010 |  | Habilitación de caminos de accesos a Cantera | 0d | 2023-05-02 | 2023-05-02 | SD.0100 | 449d | 0d | COSTOS HUARMEY |
| CO.0020 |  | Extracción de roca en cantera (con explosivos) Fase 1 | 0d | 2023-05-02 | 2023-05-02 | CO.0010 | 449d | 0d | COSTOS HUARMEY |
| CO.0025 |  | Extracción de roca en cantera (con explosivos) Fase 2 | 0d | 2023-05-02 | 2023-05-02 | CO.0020 | 452d | 0d | COSTOS HUARMEY |
| CO.0030 |  | Extracción de roca en cantera (con explosivos) Fase 3 | 0d | 2023-05-02 | 2023-05-02 | CO.0025, CO.0020 | 452d | 3d | COSTOS HUARMEY |
|  | 2 | **SELECCIÓN DE ROCA** |  | 2023-05-05 | 2023-05-05 |  |  |  |  |
| CO.0040 |  | Selección y acopio de roca (de acuerdo al diseño y tipo) Fase 1 | 0d | 2023-05-05 | 2023-05-05 | CO.0020 SS+3d | 449d | 0d | COSTOS HUARMEY |
| CO.0050 |  | Selección y acopio de roca (de acuerdo al diseño y tipo) Fase 2 | 0d | 2023-05-05 | 2023-05-05 | CO.0040, CO.0020 | 449d | 0d | COSTOS HUARMEY |
| CO.0060 |  | Transporte de material interno para acopio =1km (incluye carguío) Fase 1 | 0d | 2023-05-05 | 2023-05-05 | CO.0040 SS | 449d | 0d | COSTOS HUARMEY |
| CO.0070 |  | Transporte de material interno para acopio =1km (incluye carguío) Fase 2 | 0d | 2023-05-05 | 2023-05-05 | CO.0060 | 449d | 0d | COSTOS HUARMEY |
|  | 3 | **ELIMINACIÓN DE ROCA (DESPERDICIO)** |  | 2023-05-05 | 2023-05-05 |  |  |  |  |
| CO.0080 |  | Eliminación de material excedente = 1km (incluye carguío) | 0d | 2023-05-05 | 2023-05-05 | CO.0070 FF, CO.0010 | 449d | 0d | COSTOS HUARMEY |
| CO.0090 |  | Eliminación de material excedente > 1km | 0d | 2023-05-05 | 2023-05-05 | CO.0050 FF, CO.0070 FF, CO.0010, CO.0020 | 449d | 0d | COSTOS HUARMEY |
|  | 4 | **TRABAJOS DE CIERRE** |  | 2023-05-05 | 2023-05-05 |  |  |  |  |
| CO.0100 |  | Conformación de DME Fase 1 | 0d | 2023-05-05 | 2023-05-05 | CO.0090 SS, CO.0010, CO.0020 | 449d | 0d | COSTOS HUARMEY |
| CO.0110 |  | Conformación de DME Fase 2 | 0d | 2023-05-05 | 2023-05-05 | CO.0100, CO.0050 FF, CO.0090 FF, CO.0040 | 449d | 0d | COSTOS HUARMEY |
| CO.0120 |  | Limpieza y nivelación del terreno | 0d | 2023-05-05 | 2023-05-05 | CO.0110, CO.0030, CO.0050, CO.0070, CO.0080, CO.0010 | 449d | 0d | COSTOS HUARMEY |
|  | 4 | **CONGÓN 1** |  | 2023-05-05 | 2023-05-05 |  |  |  |  |
|  | 5 | **TRABAJOS DE CANTERA** |  | 2023-05-05 | 2023-05-05 |  |  |  |  |
| CO.0130 |  | Habilitación de caminos de accesos a Cantera | 0d | 2023-05-05 | 2023-05-05 | CO.0120, CO.0040 | 449d | 0d | COSTOS HUARMEY |
| CO.0135 |  | Extracción de roca en cantera (con explosivos) Fase 1 | 0d | 2023-05-05 | 2023-05-05 | CO.0130, CO.0040, CO.0050 | 449d | 0d | COSTOS HUARMEY |
| CO.0140 |  | Extracción de roca en cantera (con explosivos) Fase 2 | 0d | 2023-05-05 | 2023-05-05 | HUB.0020 FF, CO.0135, CO.0040, CO.0050 | 449d | 447d | COSTOS HUARMEY |
|  | 1 | **SELECCIÓN DE ROCA** |  | 2023-05-05 | 2023-05-05 |  |  |  |  |
| CO.0150 |  | Selección y acopio de roca (de acuerdo al diseño y tipo) | 0d | 2023-05-05 | 2023-05-05 | CO.0130, CO.0040 | 449d | 0d | COSTOS HUARMEY |
| CO.0160 |  | Transporte de material interno para acopio =1km (incluye carguío) | 0d | 2023-05-05 | 2023-05-05 | CO.0150 SS | 449d | 0d | COSTOS HUARMEY |

| ID | WBS | Activity | Type | Duration | Start | Finish | Predecessors | Total float | Free float | Resources | Cost |
| --- | --- | --- | --- | --- | --- | --- | --- | --- | --- | --- | --- |
|  | 2 | **ELIMINACIÓN DE ROCA (DESPERDICIO)** |  |  | 2023-05-05 | 2023-05-05 |  |  |  |  |  |
| CO.0170 |  | Eliminación de material excedente = 1km (incluye carguío) |  | 0d | 2023-05-05 | 2023-05-05 | CO.0160 FF, CO.0130, CO.0070 | 449d | 447d | COSTOS HUARMEY |  |
| CO.0180 |  | Eliminación de material excedente > 1km |  | 0d | 2023-05-05 | 2023-05-05 | CO.0160 SS | 449d | 0d | COSTOS HUARMEY |  |
|  | 3 | **TRABAJOS DE CIERRE** |  |  | 2023-05-05 | 2023-05-05 |  |  |  |  |  |
| CO.0190 |  | Conformación de DME |  | 0d | 2023-05-05 | 2023-05-05 | CO.0180 FF, CO.0130, CO.0070 | 449d | 0d | COSTOS HUARMEY |  |
| CO.0200 |  | Limpieza y nivelación del terreno |  | 0d | 2023-05-05 | 2023-05-05 | CO.0190, CO.0180, CO.0210 FF, CO.0220 FF, HUB.0010 FF | 450d |  | COSTOS HUARMEY |  |
|  | 5 | **SEGURIDAD, SALUD Y MEDIO AMBIENTE** |  |  | 2023-05-02 | 2023-05-04 |  |  |  |  |  |
| CO.0210 |  | Mitigación de impacto ambiental | level of effort | 3d | 2023-05-02 | 2023-05-04 | CO.0010 SS | 450d | 0d | COSTOS HUARMEY [117707 h] | 117,706.84 |
|  | 6 | **CONTROL DE TOPOGRAFÍA** |  |  | 2023-05-02 | 2023-05-04 |  |  |  |  |  |
| CO.0220 |  | Control topográfico de los trabajos | level of effort | 3d | 2023-05-02 | 2023-05-04 | CO.0010 SS | 450d | 0d | COSTOS HUARMEY [73820.7 h] | 73,820.67 |
|  | 6 | **QUEBRADA MALVAS** |  |  | 2023-09-16 | 2023-09-27 |  |  |  |  |  |
|  | 1 | **OBRAS PRELIMINARES** |  |  | 2023-09-16 | 2023-09-26 |  |  |  |  |  |
| QM.0010 |  | Movilización y desmovilización de maquinaria | level of effort | 9d | 2023-09-16 | 2023-09-26 | A2080 SS | 330d | 0d | COSTOS HUARMEY [193822 h] | 193,821.93 |
| QM.0020 |  | Ensayos de roca (determinado por el proveedor) | level of effort | 5d | 2023-09-16 | 2023-09-21 | A2090 SS | 330d | 0d | COSTOS HUARMEY [31242 h] | 31,241.96 |
|  | 3 | **ROCA 2** |  |  | 2023-09-16 | 2023-09-22 |  |  |  |  |  |
|  | 1 | **TRABAJOS DE CANTERA** |  |  | 2023-09-16 | 2023-09-16 |  |  |  |  |  |
| A2080 |  | Habilitación de caminos de accesos a Cantera |  | 0d | 2023-09-16 | 2023-09-16 | QA.0110 | 330d | 0d | COSTOS HUARMEY |  |
| A2090 |  | Extracción de roca en cantera (con explosivos) Fase 1 |  | 0d | 2023-09-16 | 2023-09-16 | A2080 | 330d | 0d | COSTOS HUARMEY |  |
| A2095 |  | Extracción de roca en cantera (con explosivos) Fase 2 |  | 0d | 2023-09-16 | 2023-09-16 | A2090 | 335d | 0d | COSTOS HUARMEY |  |
| A2100 |  | Extracción de roca en cantera (con explosivos) Fase 3 |  | 0d | 2023-09-16 | 2023-09-16 | A2090, A2080, A2095 | 335d | 5d | COSTOS HUARMEY |  |
|  | 2 | **SELECCIÓN DE ROCA** |  |  | 2023-09-22 | 2023-09-22 |  |  |  |  |  |
| QM.0060 |  | Selección y acopio de roca (de acuerdo al diseño y tipo) |  | 0d | 2023-09-22 | 2023-09-22 | A2090 SS+5d, A2100 FF, A2080 | 330d | 0d | COSTOS HUARMEY |  |
| QM.0070 |  | Transporte de material interno para acopio =1km (incluye carguío) |  | 0d | 2023-09-22 | 2023-09-22 | QM.0060 FF, A2080 | 330d | 0d | COSTOS HUARMEY |  |
|  | 3 | **ELIMINACIÓN DE ROCA (DESPERDICIO)** |  |  | 2023-09-22 | 2023-09-22 |  |  |  |  |  |
| QM.0080 |  | Eliminación de material excedente = 1km (incluye carguío) |  | 0d | 2023-09-22 | 2023-09-22 | QM.0060 FF, A2080 | 330d | 0d | COSTOS HUARMEY |  |
| QM.0090 |  | Eliminación de material excedente > 1km |  | 0d | 2023-09-22 | 2023-09-22 | QM.0060 FF, A2080 | 330d | 0d | COSTOS HUARMEY |  |

| ID | WBS | Activity | Type | Duration | Start | Finish | Predecessors | Total float | Free float | Resources | Cost |
| --- | --- | --- | --- | --- | --- | --- | --- | --- | --- | --- | --- |
|  | 4 | **TRABAJO DE CIERRE** |  |  | 2023-09-22 | 2023-09-22 |  |  |  |  |  |
| QM.0100 |  | Conformación de DME |  | 0d | 2023-09-22 | 2023-09-22 | QM.0090 FF, A2080 | 330d | 0d | COSTOS HUARMEY |  |
| QM.0110 |  | Limpieza y nivelación del terreno |  | 0d | 2023-09-22 | 2023-09-22 | QM.0100, QM.0090, QM.0070, QM.0080, A2080 | 330d | 0d | COSTOS HUARMEY |  |
|  | 4 | **CERRO MALVAS** |  |  | 2023-09-22 | 2023-09-27 |  |  |  |  |  |
|  | 1 | **TRABAJOS DE CANTERA** |  |  | 2023-09-22 | 2023-09-22 |  |  |  |  |  |
| QM.0120 |  | Habilitación de caminos de accesos a Cantera |  | 0d | 2023-09-22 | 2023-09-22 | QM.0110 | 330d | 0d | COSTOS HUARMEY |  |
| QM.0130 |  | Extracción de roca en cantera (con explosivos) Fase 1 |  | 0d | 2023-09-22 | 2023-09-22 | QM.0120, A2090 | 330d | 0d | COSTOS HUARMEY |  |
| QM.0220 |  | Extracción de roca en cantera (con explosivos) Fase 2 |  | 0d | 2023-09-22 | 2023-09-22 | QM.0130, QM.0020 FF, QM.0120 | 330d | 0d | COSTOS HUARMEY |  |
|  | 2 | **SELECCIÓN DE ROCA** |  |  | 2023-09-27 | 2023-09-27 |  |  |  |  |  |
| QM.0140 |  | Selección y acopio de roca (de acuerdo al diseño y tipo) |  | 0d | 2023-09-27 | 2023-09-27 | QM.0220 FF+4d, QM.0120 | 330d | 0d | COSTOS HUARMEY |  |
| QM.0150 |  | Transporte de material interno para acopio =1km (incluye carguío) |  | 0d | 2023-09-27 | 2023-09-27 | QM.0140 FF, QM.0120 | 330d | 0d | COSTOS HUARMEY |  |
|  | 3 | **ELIMINACIÓN DE ROCA (DESPERDICIO)** |  |  | 2023-09-27 | 2023-09-27 |  |  |  |  |  |
| QM.0160 |  | Eliminación de material excedente = 1km (incluye carguío) |  | 0d | 2023-09-27 | 2023-09-27 | QM.0150 FF, QM.0120 | 330d | 0d | COSTOS HUARMEY |  |
| QM.0170 |  | Eliminación de material excedente > 1km |  | 0d | 2023-09-27 | 2023-09-27 | QM.0160 FF, QM.0120, QM.0100 | 330d | 0d | COSTOS HUARMEY |  |
|  | 4 | **TRABAJOS DE CIERRE** |  |  | 2023-09-27 | 2023-09-27 |  |  |  |  |  |
| QM.0180 |  | Conformación de DME |  | 0d | 2023-09-27 | 2023-09-27 | QM.0170 FF, QM.0120 | 330d | 0d | COSTOS HUARMEY |  |
| QM.0190 |  | Limpieza y nivelación del terreno |  | 0d | 2023-09-27 | 2023-09-27 | QM.0180, QM.0200 FF, QM.0210 FF, QM.0010 FF, QM.0120, QM.0100 | 330d |  | COSTOS HUARMEY |  |
|  | 5 | **SEGURIDAD, SALUD Y MEDIO AMBIENTE** |  |  | 2023-09-16 | 2023-09-26 |  |  |  |  |  |
| QM.0200 |  | Mitigación de impacto ambiental | level of effort | 9d | 2023-09-16 | 2023-09-26 | A2080 SS | 330d | 0d | COSTOS HUARMEY [311684 h] | 311,684.12 |
|  | 6 | **CONTROL DE TOPOGRAFÍA** |  |  | 2023-09-16 | 2023-09-26 |  |  |  |  |  |
| QM.0210 |  | Control topográfico de los trabajos | level of effort | 9d | 2023-09-16 | 2023-09-26 | A2080 SS | 330d | 0d | COSTOS HUARMEY [195475 h] | 195,474.88 |
|  | 8 | **QUEBRADA AIJA** |  |  | 2023-09-14 | 2023-09-16 |  |  |  |  |  |
|  | 1 | **OBRAS PRELIMINARES** |  |  | 2023-09-14 | 2023-09-15 |  |  |  |  |  |
| QA.0010 |  | Movilización y desmovilización de maquinaria | level of effort | 2d | 2023-09-14 | 2023-09-15 | QA.0040 SS | 330d | 0d | COSTOS HUARMEY [52286.2 h] | 52,286.23 |
| QA.0020 |  | Ensayos de roca (determinado por el proveedor) | level of effort | 0d | 2023-09-14 | 2023-09-14 | QA.0050 SS | 330d | 0d | COSTOS HUARMEY |  |

| ID | WBS | Activity | Type | Duration | Start | Finish | Predecessors | Total float | Free float | Resources | Cost |
| --- | --- | --- | --- | --- | --- | --- | --- | --- | --- | --- | --- |
|  | 3 | **CERRO AIJA** |  |  | 2023-09-14 | 2023-09-16 |  |  |  |  |  |
|  | 1 | **TRABAJOS DE CANTERA** |  |  | 2023-09-14 | 2023-09-14 |  |  |  |  |  |
| QA.0040 |  | Habilitación de caminos de accesos a Cantera |  | 0d | 2023-09-14 | 2023-09-14 | SD.0110 | 330d | 0d | COSTOS HUARMEY |  |
| QA.0050 |  | Extracción de roca en cantera (con explosivos) Fase 1 |  | 0d | 2023-09-14 | 2023-09-14 | QA.0040 | 330d | 0d | COSTOS HUARMEY |  |
| QA.0140 |  | Extracción de roca en cantera (con explosivos) Fase 2 |  | 0d | 2023-09-14 | 2023-09-14 | QA.0050, QA.0040 | 330d | 0d | COSTOS HUARMEY |  |
|  | 2 | **SELECCIÓN DE ROCA** |  |  | 2023-09-14 | 2023-09-16 |  |  |  |  |  |
| QA.0060 |  | Selección y acopio de roca (de acuerdo al diseño y tipo) |  | 0d | 2023-09-14 | 2023-09-14 | QA.0020 FF, QA.0140 FF, QA.0040 | 330d | 0d | COSTOS HUARMEY |  |
| QA.0070 |  | Transporte de material interno para acopio =1km (incluye carguío) |  | 0d | 2023-09-16 | 2023-09-16 | QA.0060 SS+2d | 330d | 0d | COSTOS HUARMEY |  |
|  | 3 | **ELIMINACIÓN DE ROCA (DESPERDICIO)** |  |  | 2023-09-14 | 2023-09-16 |  |  |  |  |  |
| QA.0090 |  | Eliminación de material excedente > 1km |  | 0d | 2023-09-14 | 2023-09-14 | QA.0060 FF | 332d | 2d | COSTOS HUARMEY |  |
| QA.0080 |  | Eliminación de material excedente = 1km (incluye carguío) |  | 0d | 2023-09-16 | 2023-09-16 | QA.0070 FF, QA.0040 | 330d | 0d | COSTOS HUARMEY |  |
|  | 4 | **TRABAJO DE CIERRE** |  |  | 2023-09-14 | 2023-09-16 |  |  |  |  |  |
| QA.0100 |  | Conformación de DME |  | 0d | 2023-09-14 | 2023-09-14 | QA.0060 FF, QA.0040 | 332d | 2d | COSTOS HUARMEY |  |
| QA.0110 |  | Limpieza y nivelación del terreno |  | 0d | 2023-09-16 | 2023-09-16 | QA.0100, QA.0090, QA.0120 FF, QA.0130 FF, QA.0080, QA.0010 FF, QA.0140 | 330d | 0d | COSTOS HUARMEY |  |
|  | 4 | **SEGURIDAD, SALUD Y MEDIO AMBIENTE** |  |  | 2023-09-14 | 2023-09-15 |  |  |  |  |  |
| QA.0120 |  | Mitigación de impacto ambiental | level of effort | 2d | 2023-09-14 | 2023-09-15 | QA.0040 SS | 330d | 0d | COSTOS HUARMEY [84081.2 h] | 84,081.23 |
|  | 5 | **CONTROL DE TOPOGRAFÍA** |  |  | 2023-09-14 | 2023-09-15 |  |  |  |  |  |
| QA.0130 |  | Control topográfico de los trabajos | level of effort | 2d | 2023-09-14 | 2023-09-15 | QA.0040 SS | 330d | 0d | COSTOS HUARMEY [52732.1 h] | 52,732.13 |
|  | 9 | **SAN DAMIÁN** |  |  | 2023-01-25 | 2023-09-13 |  |  |  |  |  |
|  | 1 | **OBRAS PRELIMINARES** |  |  | 2023-01-25 | 2023-09-13 |  |  |  |  |  |
| SD.0010 |  | Movilización y desmovilización de maquinaria | level of effort | 192d | 2023-01-25 | 2023-09-13 | SD.0040 SS | 330d | 0d | COSTOS HUARMEY [48052.5 h] | 48,052.5 |
| SD.0020 |  | Ensayos de roca (determinado por el proveedor) | level of effort | 50d | 2023-01-28 | 2023-03-27 | SD.0050 SS | 468d | 0d | COSTOS HUARMEY [4303.07 h] | 4,303.07 |
|  | 3 | **ROCA IRMAN** |  |  | 2023-01-25 | 2023-09-13 |  |  |  |  |  |
|  | 1 | **TRABAJOS DE CANTERA** |  |  | 2023-01-25 | 2023-03-27 |  |  |  |  |  |
| SD.0040 |  | Habilitación de caminos de accesos a Cantera |  | 3d | 2023-01-25 | 2023-01-27 | HC.0050 SS | 330d | 0d | COSTOS HUARMEY [75738.7 h] | 75,738.7 |
| SD.0050 |  | Extracción de roca en cantera (con explosivos) Fase 1 |  | 25d | 2023-01-28 | 2023-02-25 | SD.0040 | 441d | 0d | COSTOS HUARMEY [1736328 h] | 1,736,327.76 |
| SD.0140 |  | Extracción de roca en cantera (con explosivos) Fase 2 |  | 25d | 2023-02-27 | 2023-03-27 | SD.0050, SD.0020 FF, SD.0040 | 468d | 138d | COSTOS HUARMEY [1736328 h] | 1,736,327.76 |

| ID | WBS | Activity | Type | Duration | Start | Finish | Predecessors | Total float | Free float | Resources | Cost |
| --- | --- | --- | --- | --- | --- | --- | --- | --- | --- | --- | --- |
|  | 2 | **SELECCIÓN DE ROCA** |  |  | 2023-01-28 | 2023-07-26 |  |  |  |  |  |
| SD.0060 |  | Selección y acopio de roca (de acuerdo al diseño y tipo) Fase 1 |  | 75d | 2023-01-28 | 2023-04-27 | SD.0040 | 368d | 0d | COSTOS HUARMEY [1331845 h] | 1,331,844.81 |
| SD.0070 |  | Transporte de material interno para acopio =1km (incluye carguío) Fase 1 |  | 49d | 2023-01-28 | 2023-03-25 | SD.0040 | 445d | 0d | COSTOS HUARMEY [403603 h] | 403,602.67 |
| SD.0075 |  | Transporte de material interno para acopio =1km (incluye carguío) Fase 2 |  | 24d | 2023-03-27 | 2023-04-25 | SD.0070 | 445d | 115d | COSTOS HUARMEY [403603 h] | 403,602.68 |
| SD.0065 |  | Selección y acopio de roca (de acuerdo al diseño y tipo) Fase 2 |  | 75d | 2023-04-28 | 2023-07-26 | SD.0060 | 368d | 38d | COSTOS HUARMEY [1331845 h] | 1,331,844.81 |
|  | 3 | **ELIMINACIÓN DE ROCA (DESPERDICIO)** |  |  | 2023-01-28 | 2023-09-12 |  |  |  |  |  |
| SD.0080 |  | Eliminación de material excedente = 1km (incluye carguío) Fase 1 |  | 94d | 2023-01-28 | 2023-05-20 | SD.0040 | 330d | 0d | COSTOS HUARMEY [191851 h] | 191,851.38 |
| SD.0090 |  | Eliminación de material excedente > 1km Fase 1 |  | 9d | 2023-01-28 | 2023-02-07 | SD.0040 | 505d | 0d | COSTOS HUARMEY [261733 h] | 261,732.89 |
| SD.0150 |  | Eliminación de material excedente > 1km Fase 2 |  | 4d | 2023-02-08 | 2023-02-11 | SD.0090 | 505d | 175d | COSTOS HUARMEY [261733 h] | 261,732.89 |
| SD.0085 |  | Eliminación de material excedente = 1km (incluye carguío) Fase 2 |  | 94d | 2023-05-22 | 2023-09-12 | SD.0080 | 330d | 0d | COSTOS HUARMEY [191851 h] | 191,851.38 |
|  | 4 | **TRABAJOS DE CIERRE** |  |  | 2023-02-27 | 2023-09-13 |  |  |  |  |  |
| SD.0100 |  | Conformación de DME |  | 52d | 2023-02-27 | 2023-04-29 | SD.0090 FF, SD.0050, SD.0040 | 441d | 0d | COSTOS HUARMEY [207156 h] | 207,156.3 |
| SD.0110 |  | Limpieza y nivelación del terreno |  | 1d | 2023-09-13 | 2023-09-13 | SD.0100, SD.0090, SD.0120 FF, SD.0130 FF, SD.0010 FF, SD.0140, SD.0080, SD.0050, SD.0060, SD.0065, SD.0075, SD.0085, SD.0150 | 330d | 0d | COSTOS HUARMEY [901.67 h] | 901.67 |
|  | 4 | **SEGURIDAD, SALUD Y MEDIO AMBIENTE** |  |  | 2023-01-25 | 2023-09-13 |  |  |  |  |  |
| SD.0120 |  | Mitigación de impacto ambiental | level of effort | 192d | 2023-01-25 | 2023-09-13 | SD.0040 SS | 330d | 0d | COSTOS HUARMEY [77273 h] | 77,272.99 |
|  | 5 | **CONTROL DE TOPOGRAFÍA** |  |  | 2023-01-25 | 2023-09-13 |  |  |  |  |  |
| SD.0130 |  | Control topográfico de los trabajos | level of effort | 192d | 2023-01-25 | 2023-09-13 | SD.0040 SS | 330d | 0d | COSTOS HUARMEY [48462.3 h] | 48,462.3 |
|  | 7 | **OTROS** |  |  | 2022-10-11 | 2024-10-23 |  |  |  |  |  |
| VA.0040 |  | Examenes Médicos - Personal Directo (Ingreso y salida) |  | 58d | 2022-10-11 | 2022-12-20 | HT.0020 SS | 244d | 0d | COSTOS HUARMEY [219993 h] | 219,993.16 |
| VA.0010 |  | Transporte Interno - Personal Directo (Camioneta+chofer+combustible a doble turno) | level of effort | 591d | 2022-11-16 | 2024-10-23 | OP.0050 SS | 0d |  | COSTOS HUARMEY [2959852 h] | 2,959,852.09 |
| VA.0070 |  | AGUA - Personal Directo (1lt/persona/dia=30lt/mes) | level of effort | 591d | 2022-11-16 | 2024-10-23 | OP.0050 SS | 0d |  | COSTOS HUARMEY [154665 h] | 154,665.45 |
| VA.0020 |  | EPPS - Personal Directo (renovacion cada 6 meses) |  | 15d | 2022-12-21 | 2023-01-06 | VA.0040 | 349d | 0d | COSTOS HUARMEY [642196 h] | 642,195.61 |
| VA.0050 |  | Certificado de Operadores - Personal Directo |  | 150d | 2023-01-07 | 2023-07-05 | VA.0020 | 354d | 33d | COSTOS HUARMEY [1186.78 h] | 1,186.78 |
| VA.0060 |  | Charla de Inducción - Personal Directo |  | 150d | 2023-01-07 | 2023-07-05 | VA.0040, VA.0020 | 354d | 33d | COSTOS HUARMEY [49399.7 h] | 49,399.66 |
| VA.0030 |  | EPPS - Personal Directo (renovacion cada 6 meses) |  | 15d | 2023-08-16 | 2023-09-02 | VA.0020 FS+183d, VA.0050, VA.0060 | 349d | 347d | COSTOS HUARMEY [642196 h] | 642,195.62 |
