# CANTERAS - HUARMEY - LB0 Rev03 LABOR

Schedule from Primavera P6, 2022-10-11 to 2024-04-16, data date 2022-10-11.
ESTE PROYECTO PERTENECE A LA EXPLOTACIÓN DE LA CANTERA / CASMA.

## Calendars

- Calendario Huarmey Project: Mon-Sat 02:00-22:00; Sun off. Exceptions (off unless hours are given): 2022-11-01, 2022-12-08 to 2022-12-09, 2022-12-25, 2023-01-01, 2023-04-06 to 2023-04-07, 2023-05-01, 2023-06-29, 2023-07-28 to 2023-07-29, 2023-08-30, 2023-11-01, 2023-12-08 to 2023-12-09, 2023-12-25, 2024-01-01, 2024-03-28 to 2024-03-29.

## Resources

| Resource | Group | Notes |
| --- | --- | --- |
| CONSTRUCCION HH | labor | SE TIENE HH DEL CAPEX ORIGINAL |
| EXTRACCIÓN DE ROCA | material | ï»¿ |

## Schedule

| ID | WBS | Activity | Type | Duration | Start | Finish | Predecessors | Total float | Free float | Resources |
| --- | --- | --- | --- | --- | --- | --- | --- | --- | --- | --- |
|  | 1 | **HITOS PRINCIPALES** |  |  | 2022-10-11 | 2024-04-16 |  |  |  |  |
| HT.0020 |  | Inicio de Proyecto | milestone | 0d | 2022-10-11 | 2022-10-11 |  | 0d |  |  |
| HT.0010 |  | Fin de Proyecto | milestone | 0d | 2024-04-16 | 2024-04-16 | HU.0150 FF, VA.0070 FF, VA.0010 FF, CO.0200 FF, QM.0190 FF | 0d |  |  |
|  | 2 | **OBRAS PROVISIONALES** |  |  | 2022-10-12 | 2023-01-12 |  |  |  |  |
|  | 1 | **TRAMITES, GESTIÓN Y OBTENCIÓN DE PERMISOS** |  |  | 2022-10-12 | 2023-01-12 |  |  |  |  |
| OP.0030 |  | Tramite, gestión y obtención de permisos para almacenamiento y uso de Polvorín |  | 29d | 2022-10-12 | 2022-11-15 | HT.0020 SS+1d | 0d |  |  |
| OP.0010 |  | Tramite, gestión y obtención de permisos para uso y adquisición de explosivos |  | 63d | 2022-10-14 | 2022-12-29 | OP.0030 SS+2d | 38d |  |  |
| OP.0020 |  | Tramite, gestión y obtención de permisos para manipulación de explosivos |  | 36d | 2022-11-16 | 2022-12-29 | OP.0030 | 5d | 0d |  |
| OP.0040 |  | Trámite, gestión y obtención de permisos para explotación de canteras |  | 9d | 2022-11-16 | 2022-11-25 | OP.0030 | 28d |  |  |
| OP.0050 |  | Instalación de campamento, patio taller y oficinas |  | 36d | 2022-11-16 | 2022-12-29 | OP.0030 | 38d |  | CONSTRUCCION HH [935.15 h] |
| OP.0060 |  | Construcción e implementación de polvorín |  | 48d | 2022-11-16 | 2023-01-12 | OP.0030 | 211d | 104d |  |
|  | 3 | **HITOS DE CONSTRUCCIÓN** |  |  | 2022-11-16 | 2023-08-07 |  |  |  |  |
| HC.0010 |  | Aprobación de ingreso a cantera - Huarmey Parte Alta | milestone | 0d | 2022-11-16 | 2022-11-16 | OP.0030 | 0d |  |  |
| HC.0050 |  | Aprobación de ingreso a cantera - San Damian | milestone | 0d | 2023-01-25 | 2023-01-25 | OP.0020 FS+22d | 5d | 0d |  |
| HC.0020 |  | Aprobación de ingreso a cantera - Huarmey Parte Baja | milestone | 0d | 2023-05-18 | 2023-05-18 | OP.0020, OP.0060, QA.0040 SS | 107d |  |  |
| HC.0040 |  | Aprobación de ingreso a cantera - Quebrada Aija | milestone | 0d | 2023-05-18 | 2023-05-18 | QA.0040 SS | 107d |  |  |
| HC.0030 |  | Aprobación de ingreso a cantera - Quebrada Malvas | milestone | 0d | 2023-08-07 | 2023-08-07 | A2080 SS | 143d | 140d |  |
|  | 4 | **HUARMEY (PARTE ALTA)** |  |  | 2022-11-24 | 2024-04-16 |  |  |  |  |
|  | 1 | **OBRAS PRELIMINARES** |  |  | 2022-11-24 | 2024-04-16 |  |  |  |  |
| HU.0010 |  | Movilización y desmovilización de maquinaria | level of effort | 421d | 2022-11-24 | 2024-04-16 | T1.0010 SS | 0d |  |  |
| HU.0020 |  | Ensayos de Roca (determinado por el proveedor) | level of effort | 387d | 2022-12-31 | 2024-04-11 | T1.0020 SS | 3d | 0d |  |
|  | 3 | **TAYCA 1** |  |  | 2022-11-24 | 2023-10-13 |  |  |  |  |
|  | 1 | **TAYCA 1** |  |  | 2022-11-24 | 2023-10-07 |  |  |  |  |
|  | 1 | **TRABAJOS DE CANTERA** |  |  | 2022-11-24 | 2023-09-23 |  |  |  |  |
| T1.0010 |  | Habilitación de caminos de accesos |  | 26d | 2022-11-24 | 2022-12-26 | HC.0010 SS+7d | 0d |  | CONSTRUCCION HH [2398.07 h] |
| T1.0020 |  | Extracción de roca en cantera (con explosivos) Fase 1 |  | 37d | 2022-12-31 | 2023-02-11 | T1.0010 FS+4d, OP.0040 | 0d |  | CONSTRUCCION HH [19194 h]; EXTRACCIÓN DE ROCA [98144.3] |
| T1.0030 |  | Extracción de roca en cantera (con explosivos) Fase 2 |  | 37d | 2023-02-13 | 2023-03-27 | T1.0020, OP.0010, OP.0040, OP.0050, VA.0040, T1.0010, OP.0030 | 0d |  | CONSTRUCCION HH [19194 h]; EXTRACCIÓN DE ROCA [98144.3] |
| T1.0040 |  | Extracción de roca en cantera (con explosivos) Fase 3 |  | 37d | 2023-03-28 | 2023-05-12 | T1.0030, T1.0260, T1.0140, T1.0270, T1.0080, OP.0030 | 0d |  | CONSTRUCCION HH [19194 h]; EXTRACCIÓN DE ROCA [98144.3] |
| T1.0050 |  | Extracción de roca en cantera (con explosivos) Fase 4 |  | 37d | 2023-05-13 | 2023-06-24 | T1.0040, T1.0150, T1.0090, T1.0210, T1.0030, T1.0090 FF, OP.0030 | 0d |  | CONSTRUCCION HH [19194 h]; EXTRACCIÓN DE ROCA [98144.3] |
| T1.0060 |  | Extracción de roca en cantera (con explosivos) Fase 5 |  | 37d | 2023-06-26 | 2023-08-10 | T1.0050, OP.0030 | 0d |  | CONSTRUCCION HH [19194 h]; EXTRACCIÓN DE ROCA [98144.3] |
| T1.0070 |  | Extracción de roca en cantera (con explosivos) Fase 6 |  | 37d | 2023-08-11 | 2023-09-23 | T1.0060, VA.0050, VA.0060, T1.0110, HC.0020 SF, HC.0040 SF, OP.0030 | 0d |  | CONSTRUCCION HH [19194 h]; EXTRACCIÓN DE ROCA [98144.3] |

| ID | WBS | Activity | Duration | Start | Finish | Predecessors | Total float | Free float | Resources |
| --- | --- | --- | --- | --- | --- | --- | --- | --- | --- |
|  | SELECCION DE ROCA | **SELECCION DE ROCA** |  | 2022-12-31 | 2023-10-07 |  |  |  |  |
| T1.0080 |  | Selección y acopio de roca (de acuerdo al diseño y tipo) Fase 1 | 39d | 2022-12-31 | 2023-02-14 | T1.0010 FS+4d | 0d |  | CONSTRUCCION HH [14417.4 h] |
| T1.0140 |  | Transporte de material interno para acopio =1km (incluye carguío) Fase 1 | 45d | 2022-12-31 | 2023-02-21 | T1.0080 SS | 21d | 0d | CONSTRUCCION HH [3582.27 h] |
| T1.0090 |  | Selección y acopio de roca (de acuerdo al diseño y tipo) Fase 2 | 39d | 2023-02-15 | 2023-03-31 | T1.0080, T1.0010, OP.0030 | 0d |  | CONSTRUCCION HH [14417.4 h] |
| T1.0150 |  | Transporte de material interno para acopio =1km (incluye carguío) Fase 2 | 45d | 2023-02-22 | 2023-04-17 | T1.0140, T1.0080, T1.0200 | 21d | 0d | CONSTRUCCION HH [3582.27 h] |
| T1.0100 |  | Selección y acopio de roca (de acuerdo al diseño y tipo) Fase 3 | 39d | 2023-04-01 | 2023-05-19 | T1.0090, T1.0140, T1.0080, T1.0020, T1.0010, OP.0030 | 0d |  | CONSTRUCCION HH [14417.4 h] |
| T1.0160 |  | Transporte de material interno para acopio =1km (incluye carguío) Fase 3 | 36d | 2023-04-18 | 2023-05-30 | T1.0150, T1.0090 | 36d | 0d | CONSTRUCCION HH [3582.27 h] |
| T1.0110 |  | Selección y acopio de roca (de acuerdo al diseño y tipo) Fase 4 | 39d | 2023-05-20 | 2023-07-05 | T1.0100, T1.0150, T1.0020, T1.0010, T1.0030, OP.0030 | 0d |  | CONSTRUCCION HH [14417.4 h] |
| T1.0170 |  | Transporte de material interno para acopio =1km (incluye carguío) Fase 4 | 30d | 2023-05-31 | 2023-07-05 | T1.0160, T1.0100, T1.0220 | 36d | 0d | CONSTRUCCION HH [3582.27 h] |
| T1.0120 |  | Selección y acopio de roca (de acuerdo al diseño y tipo) Fase 5 | 39d | 2023-07-06 | 2023-08-22 | T1.0110, T1.0100, T1.0020, T1.0010, T1.0030, T1.0040, OP.0030 | 0d |  | CONSTRUCCION HH [14417.4 h] |
| T1.0180 |  | Transporte de material interno para acopio =1km (incluye carguío) Fase 5 | 30d | 2023-07-06 | 2023-08-11 | T1.0170 | 36d | 0d | CONSTRUCCION HH [3582.27 h] |
| T1.0190 |  | Transporte de material interno para acopio =1km (incluye carguío) Fase 6 | 30d | 2023-08-12 | 2023-09-16 | T1.0180 | 37d | 18d | CONSTRUCCION HH [3582.27 h] |
| T1.0130 |  | Selección y acopio de roca (de acuerdo al diseño y tipo) Fase 6 | 39d | 2023-08-23 | 2023-10-07 | T1.0120, T1.0170, T1.0020, T1.0030, T1.0050, OP.0030 | 0d |  | CONSTRUCCION HH [14417.4 h] |
|  | 2 | **ELLIMINACIÓN DE ROCA (DESPERDICIO)** |  | 2022-12-31 | 2023-10-07 |  |  |  |  |
| T1.0200 |  | Eliminación de material excedente = 1km (incluye carguío) Fase 1 | 36d | 2022-12-31 | 2023-02-10 | T1.0010 FS+4d | 30d | 0d | CONSTRUCCION HH [3086.18 h] |
| T1.0260 |  | Eliminación de material excedente > 1km Fase 1 | 31d | 2022-12-31 | 2023-02-04 | T1.0010 FS+4d | 3d | 0d | CONSTRUCCION HH [2695.7 h] |
| T1.0270 |  | Eliminación de material excedente > 1km Fase 2 | 31d | 2023-02-06 | 2023-03-13 | T1.0260 | 3d | 0d | CONSTRUCCION HH [2695.7 h] |
| T1.0210 |  | Eliminación de material excedente = 1km (incluye carguío) Fase 2 | 36d | 2023-02-11 | 2023-03-24 | T1.0200 | 34d | 0d | CONSTRUCCION HH [3086.18 h] |
| T1.0280 |  | Eliminación de material excedente > 1km Fase 3 | 31d | 2023-03-14 | 2023-04-20 | T1.0270 | 3d | 0d | CONSTRUCCION HH [2695.7 h] |
| T1.0220 |  | Eliminación de material excedente = 1km (incluye carguío) Fase 3 | 36d | 2023-03-25 | 2023-05-09 | T1.0210 | 34d | 0d | CONSTRUCCION HH [3086.18 h] |
| T1.0290 |  | Eliminación de material excedente > 1km Fase 4 | 46d | 2023-04-21 | 2023-06-14 | T1.0280 | 3d | 0d | CONSTRUCCION HH [2695.7 h] |
| T1.0230 |  | Eliminación de material excedente = 1km (incluye carguío) Fase 4 | 36d | 2023-05-10 | 2023-06-20 | T1.0220 | 37d | 0d | CONSTRUCCION HH [3086.18 h] |
| T1.0300 |  | Eliminación de material excedente > 1km Fase 5 | 46d | 2023-06-15 | 2023-08-10 | T1.0290, T1.0220 | 3d |  | CONSTRUCCION HH [2695.7 h] |
| T1.0240 |  | Eliminación de material excedente = 1km (incluye carguío) Fase 5 | 36d | 2023-06-21 | 2023-08-04 | T1.0230, T1.0160 | 37d | 6d | CONSTRUCCION HH [3086.18 h] |
| T1.0250 |  | Eliminación de material excedente = 1km (incluye carguío) Fase 6 | 36d | 2023-08-12 | 2023-09-23 | T1.0240, T1.0070 FF | 31d | 12d | CONSTRUCCION HH [3086.18 h] |
| T1.0310 |  | Eliminación de material excedente > 1km Fase 6 | 46d | 2023-08-15 | 2023-10-07 | T1.0300, T1.0130 FF, T1.0110, T1.0080, T1.0090, T1.0110 FF | 0d |  | CONSTRUCCION HH [2695.7 h] |

| ID | WBS | Activity | Duration | Start | Finish | Predecessors | Total float | Free float | Resources |
| --- | --- | --- | --- | --- | --- | --- | --- | --- | --- |
|  | 7 | **TRABAJOS DE CIERRE** |  | 2022-12-31 | 2023-10-13 |  |  |  |  |
| HU.0030 |  | Conformación de DME Fase 1 | 37d | 2022-12-31 | 2023-02-11 | T1.0010 FS+4d | 12d | 0d | CONSTRUCCION HH [1177.73 h] |
| HU.0040 |  | Conformación de DME Fase 2 | 37d | 2023-02-13 | 2023-03-27 | HU.0030 | 12d | 0d | CONSTRUCCION HH [1177.73 h] |
| HU.0050 |  | Conformación de DME Fase 3 | 37d | 2023-03-28 | 2023-05-12 | HU.0040 | 12d | 0d | CONSTRUCCION HH [1177.73 h] |
| HU.0060 |  | Conformación de DME Fase 4 | 37d | 2023-05-13 | 2023-06-24 | HU.0050 | 12d | 0d | CONSTRUCCION HH [1177.73 h] |
| HU.0070 |  | Conformación de DME Fase 5 | 37d | 2023-06-26 | 2023-08-10 | HU.0060 | 12d | 0d | CONSTRUCCION HH [1177.73 h] |
| HU.0080 |  | Conformación de DME Fase 6 | 37d | 2023-08-25 | 2023-10-07 | HU.0070, T1.0310 FF | 0d |  | CONSTRUCCION HH [1177.73 h] |
| HU.0090 |  | Limpieza y nivelación del terreno | 5d | 2023-10-09 | 2023-10-13 | HU.0030, T1.0310, HU.0080, T1.0190, T1.0250 | 19d | 16d | CONSTRUCCION HH [37.55 h] |
|  | 5 | **TAYCA 2** |  | 2023-08-11 | 2024-04-16 |  |  |  |  |
|  | 0 | **TAYCA 2** |  | 2023-08-11 | 2024-04-16 |  |  |  |  |
|  | 1 | **TRABAJOS DE CANTERA** |  | 2023-08-11 | 2024-04-11 |  |  |  |  |
| T2.0010 |  | Habilitación de caminos de accesos a Cantera | 9d | 2023-08-11 | 2023-08-21 | HU.0070 | 28d |  | CONSTRUCCION HH [1757.85 h] |
| T2.0020 |  | Extracción de roca en cantera (con explosivos) Fase 1 | 33d | 2023-09-25 | 2023-11-02 | T2.0010, T1.0070, CO.0020, T1.0180, T1.0170, T1.0240, T1.0230, T1.0300 | 0d |  | CONSTRUCCION HH [16883.7 h]; EXTRACCIÓN DE ROCA [86330.9] |
| T2.0030 |  | Extracción de roca en cantera (con explosivos) Fase 2 | 33d | 2023-11-03 | 2023-12-13 | T2.0020 | 3d | 0d | CONSTRUCCION HH [16883.7 h]; EXTRACCIÓN DE ROCA [86330.9] |
| T2.0040 |  | Extracción de roca en cantera (con explosivos) Fase 3 | 33d | 2023-12-14 | 2024-01-23 | T2.0030, HC.0030 SF | 3d | 0d | CONSTRUCCION HH [16883.7 h]; EXTRACCIÓN DE ROCA [86330.9] |
| T2.0050 |  | Extracción de roca en cantera (con explosivos) Fase 4 | 33d | 2024-01-24 | 2024-03-01 | T2.0040 | 3d | 0d | CONSTRUCCION HH [16883.7 h]; EXTRACCIÓN DE ROCA [86330.9] |
| T2.0060 |  | Extracción de roca en cantera (con explosivos) Fase 5 | 33d | 2024-03-02 | 2024-04-11 | T2.0050, HU.0020 FF | 3d |  | CONSTRUCCION HH [16883.7 h]; EXTRACCIÓN DE ROCA [86330.9] |
|  | 2 | **SELECCIÓN DE ROCA** |  | 2023-09-25 | 2024-04-16 |  |  |  |  |
| T2.0070 |  | Selección y acopio de roca (de acuerdo al diseño y tipo) Fase 1 | 33d | 2023-09-25 | 2023-11-02 | T1.0070 | 3d | 0d | CONSTRUCCION HH [12682 h] |
| T2.0120 |  | Transporte de material interno para acopio =1km (incluye carguío) Fase 1 | 26d | 2023-09-25 | 2023-10-24 | T2.0020 SS, CO.0060, CO.0100, SD.0110 | 0d |  | CONSTRUCCION HH [3151.08 h] |
| T2.0130 |  | Transporte de material interno para acopio =1km (incluye carguío) Fase 2 | 26d | 2023-10-25 | 2023-11-24 | T2.0120, HU.0080 | 0d |  | CONSTRUCCION HH [3151.08 h] |
| T2.0080 |  | Selección y acopio de roca (de acuerdo al diseño y tipo) Fase 2 | 33d | 2023-11-03 | 2023-12-13 | T2.0070, VA.0030, HU.0090, CO.0080, CO.0090, CO.0120, CO.0130, T1.0120, T1.0130, T1.0250, T1.0310, CO.0030, CO.0050, CO.0070, CO.0110 | 3d | 0d | CONSTRUCCION HH [12682 h] |
| T2.0140 |  | Transporte de material interno para acopio =1km (incluye carguío) Fase 3 | 39d | 2023-11-25 | 2024-01-13 | T2.0130, T2.0120, T2.0020, T1.0310, HU.0080 | 0d |  | CONSTRUCCION HH [3151.08 h] |
| T2.0090 |  | Selección y acopio de roca (de acuerdo al diseño y tipo) Fase 3 | 33d | 2023-12-14 | 2024-01-23 | T2.0080, T1.0190, CO.0140, CO.0135 | 3d | 0d | CONSTRUCCION HH [12682 h] |
| T2.0150 |  | Transporte de material interno para acopio =1km (incluye carguío) Fase 4 | 39d | 2024-01-15 | 2024-02-28 | T2.0140, T2.0220, HU.0100, T2.0020, T1.0310, HU.0080 | 0d |  | CONSTRUCCION HH [3151.08 h] |
| T2.0100 |  | Selección y acopio de roca (de acuerdo al diseño y tipo) Fase 4 | 33d | 2024-01-24 | 2024-03-01 | T2.0090, CO.0150, CO.0160, CO.0170, CO.0180, CO.0190 | 3d | 0d | CONSTRUCCION HH [12682 h] |
| T2.0160 |  | Transporte de material interno para acopio =1km (incluye carguío) Fase 5 | 39d | 2024-02-29 | 2024-04-16 | T2.0150, T2.0140, HU.0120 | 0d |  | CONSTRUCCION HH [3151.08 h] |
| T2.0110 |  | Selección y acopio de roca (de acuerdo al diseño y tipo) Fase 5 | 33d | 2024-03-02 | 2024-04-11 | T2.0100 | 3d |  | CONSTRUCCION HH [12682 h] |

| ID | WBS | Activity | Type | Duration | Start | Finish | Predecessors | Total float | Free float | Resources |
| --- | --- | --- | --- | --- | --- | --- | --- | --- | --- | --- |
|  | 3 | **ELIMINACIÓN DE ROCA (DESPERDICIO)** |  |  | 2023-10-09 | 2024-04-08 |  |  |  |  |
| T2.0170 |  | Eliminación de material excedente = 1km (incluye carguío) Fase 1 |  | 32d | 2023-10-09 | 2023-11-15 | HU.0080 | 18d | 0d | CONSTRUCCION HH [2714.7 h] |
| T2.0220 |  | Eliminación de material excedente > 1km Fase 1 |  | 32d | 2023-10-09 | 2023-11-15 | HU.0080 | 0d |  | CONSTRUCCION HH [2371.22 h] |
| T2.0180 |  | Eliminación de material excedente = 1km (incluye carguío) Fase 2 |  | 32d | 2023-11-16 | 2023-12-26 | T2.0170, T2.0120 | 18d | 0d | CONSTRUCCION HH [2714.7 h] |
| T2.0230 |  | Eliminación de material excedente > 1km Fase 2 |  | 32d | 2023-11-16 | 2023-12-26 | T2.0220 | 6d | 0d | CONSTRUCCION HH [2371.22 h] |
| T2.0190 |  | Eliminación de material excedente = 1km (incluye carguío) Fase 3 |  | 32d | 2023-12-27 | 2024-02-02 | T2.0180, HU.0090, T2.0120 | 18d | 0d | CONSTRUCCION HH [2714.7 h] |
| T2.0240 |  | Eliminación de material excedente > 1km Fase 3 |  | 32d | 2023-12-27 | 2024-02-02 | T2.0230 | 6d | 0d | CONSTRUCCION HH [2371.22 h] |
| T2.0200 |  | Eliminación de material excedente = 1km (incluye carguío) Fase 4 |  | 21d | 2024-02-03 | 2024-02-27 | T2.0190, T2.0120 | 18d | 0d | CONSTRUCCION HH [2714.7 h] |
| T2.0250 |  | Eliminación de material excedente > 1km Fase 4 |  | 27d | 2024-02-03 | 2024-03-05 | T2.0240 | 6d | 0d | CONSTRUCCION HH [2371.22 h] |
| T2.0210 |  | Eliminación de material excedente = 1km (incluye carguío) Fase 5 |  | 21d | 2024-02-28 | 2024-03-22 | T2.0200 | 18d |  | CONSTRUCCION HH [2714.7 h] |
| T2.0260 |  | Eliminación de material excedente > 1km Fase 5 |  | 27d | 2024-03-06 | 2024-04-08 | T2.0250 | 6d |  | CONSTRUCCION HH [2371.22 h] |
|  | 6 | **TRABAJOS DE CIERRE** |  |  | 2023-10-16 | 2024-04-16 |  |  |  |  |
| HU.0100 |  | Conformación de DME Fase 1 |  | 33d | 2023-10-16 | 2023-11-23 | T2.0220 SS+6d | 0d |  | CONSTRUCCION HH [1035.97 h] |
| HU.0110 |  | Conformación de DME Fase 2 |  | 33d | 2023-11-25 | 2024-01-06 | HU.0100 FS+1d, T2.0220, T2.0120, T2.0020 | 0d |  | CONSTRUCCION HH [1035.97 h] |
| HU.0120 |  | Conformación de DME Fase 3 |  | 33d | 2024-01-08 | 2024-02-14 | HU.0110, HU.0100, T2.0130, T2.0230, T2.0120, T2.0020 | 0d |  | CONSTRUCCION HH [1035.97 h] |
| HU.0130 |  | Conformación de DME Fase 4 |  | 33d | 2024-02-15 | 2024-03-23 | HU.0120, HU.0110, T2.0140, T2.0230, T2.0120, T2.0020 | 0d |  | CONSTRUCCION HH [1035.97 h] |
| HU.0140 |  | Conformación de DME Fase 5 |  | 17d | 2024-03-25 | 2024-04-15 | HU.0130, T2.0150, T2.0230, T2.0120, T2.0140, T2.0020 | 0d |  | CONSTRUCCION HH [1035.97 h] |
| HU.0150 |  | Limpieza y nivelación del terreno |  | 1d | 2024-04-16 | 2024-04-16 | T2.0210, HU.0140, HU.0160 FF, HU.0170 FF, HU.0010 FF, T2.0110, T2.0260, T2.0060, T2.0160 FF, T2.0130, T2.0140, T2.0150, HU.0100, HU.0110, HU.0120 | 0d |  | CONSTRUCCION HH [27.52 h] |
|  | 7 | **SEGURIDAD, SALUD Y MEDIO AMBIENTE** |  |  | 2022-11-24 | 2024-04-16 |  |  |  |  |
| HU.0160 |  | Mitigación de impacto ambiental | level of effort | 421d | 2022-11-24 | 2024-04-16 | T1.0010 SS | 0d |  | CONSTRUCCION HH [3742.02 h] |
|  | 8 | **CONTROL DE TOPOGRAFÍA** |  |  | 2022-11-24 | 2024-04-16 |  |  |  |  |
| HU.0170 |  | Control topográfico de los trabajos | level of effort | 421d | 2022-11-24 | 2024-04-16 | T1.0010 SS | 0d |  | CONSTRUCCION HH [14968.1 h] |
|  | 5 | **HUARMEY (PARTE BAJA)** |  |  | 2023-05-17 | 2023-12-23 |  |  |  |  |
|  | 1 | **OBRAS PRELIMINARES** |  |  | 2023-05-17 | 2023-12-23 |  |  |  |  |
| HUB.0010 |  | Movilización y desmovilización de maquinaria | level of effort | 183d | 2023-05-17 | 2023-12-23 | CO.0010 SS | 94d | 0d |  |
| HUB.0020 |  | Ensayos de roca (determinado por el proveedor) | level of effort | 165d | 2023-05-25 | 2023-12-11 | CO.0020 SS | 5d | 0d |  |

| ID | WBS | Activity | Duration | Start | Finish | Predecessors | Total float | Free float | Resources |
| --- | --- | --- | --- | --- | --- | --- | --- | --- | --- |
|  | 3 | **CONGÓN 2** |  | 2023-05-17 | 2023-10-02 |  |  |  |  |
|  | 1 | **TRABAJOS DE CANTERA** |  | 2023-05-17 | 2023-09-07 |  |  |  |  |
| CO.0010 |  | Habilitación de caminos de accesos a Cantera | 7d | 2023-05-17 | 2023-05-24 | SD.0100 | 5d | 0d | CONSTRUCCION HH [235.58 h] |
| CO.0020 |  | Extracción de roca en cantera (con explosivos) Fase 1 | 29d | 2023-05-25 | 2023-06-27 | CO.0010 | 5d | 0d | CONSTRUCCION HH [3771.1 h]; EXTRACCIÓN DE ROCA [19282.7] |
| CO.0025 |  | Extracción de roca en cantera (con explosivos) Fase 2 | 29d | 2023-06-28 | 2023-08-03 | CO.0020 | 25d | 0d | CONSTRUCCION HH [3771.1 h]; EXTRACCIÓN DE ROCA [19282.7] |
| CO.0030 |  | Extracción de roca en cantera (con explosivos) Fase 3 | 29d | 2023-08-04 | 2023-09-07 | CO.0025, CO.0020 | 25d | 20d | CONSTRUCCION HH [3771.1 h]; EXTRACCIÓN DE ROCA [19282.7] |
|  | 2 | **SELECCIÓN DE ROCA** |  | 2023-05-29 | 2023-09-30 |  |  |  |  |
| CO.0040 |  | Selección y acopio de roca (de acuerdo al diseño y tipo) Fase 1 | 49d | 2023-05-29 | 2023-07-25 | CO.0020 SS+3d | 5d | 0d | CONSTRUCCION HH [4248.94 h] |
| CO.0060 |  | Transporte de material interno para acopio =1km (incluye carguío) Fase 1 | 52d | 2023-05-29 | 2023-07-31 | CO.0040 SS | 5d | 0d | CONSTRUCCION HH [1055.73 h] |
| CO.0050 |  | Selección y acopio de roca (de acuerdo al diseño y tipo) Fase 2 | 49d | 2023-07-26 | 2023-09-23 | CO.0040, CO.0020 | 11d | 6d | CONSTRUCCION HH [4248.94 h] |
| CO.0070 |  | Transporte de material interno para acopio =1km (incluye carguío) Fase 2 | 52d | 2023-08-01 | 2023-09-30 | CO.0060 | 5d | 0d | CONSTRUCCION HH [1055.73 h] |
|  | 3 | **ELIMINACIÓN DE ROCA (DESPERDICIO)** |  | 2023-06-21 | 2023-09-30 |  |  |  |  |
| CO.0080 |  | Eliminación de material excedente = 1km (incluye carguío) | 84d | 2023-06-21 | 2023-09-30 | CO.0070 FF, CO.0010 | 5d | 0d | CONSTRUCCION HH [1819.05 h] |
| CO.0090 |  | Eliminación de material excedente > 1km | 54d | 2023-07-27 | 2023-09-30 | CO.0050 FF, CO.0070 FF, CO.0010, CO.0020 | 5d | 0d | CONSTRUCCION HH [1588.89 h] |
|  | 4 | **TRABAJOS DE CIERRE** |  | 2023-07-27 | 2023-10-02 |  |  |  |  |
| CO.0100 |  | Conformación de DME Fase 1 | 22d | 2023-07-27 | 2023-08-23 | CO.0090 SS, CO.0010, CO.0020 | 15d | 10d | CONSTRUCCION HH [347.09 h] |
| CO.0110 |  | Conformación de DME Fase 2 | 22d | 2023-09-06 | 2023-09-30 | CO.0100, CO.0050 FF, CO.0090 FF, CO.0040 | 5d | 0d | CONSTRUCCION HH [347.09 h] |
| CO.0120 |  | Limpieza y nivelación del terreno | 1d | 2023-10-02 | 2023-10-02 | CO.0110, CO.0030, CO.0050, CO.0070, CO.0080, CO.0010 | 5d | 0d | CONSTRUCCION HH [3.69 h] |
|  | 4 | **CONGÓN 1** |  | 2023-10-03 | 2023-12-23 |  |  |  |  |
|  | 5 | **TRABAJOS DE CANTERA** |  | 2023-10-03 | 2023-12-11 |  |  |  |  |
| CO.0130 |  | Habilitación de caminos de accesos a Cantera | 7d | 2023-10-03 | 2023-10-10 | CO.0120, CO.0040 | 5d | 0d | CONSTRUCCION HH [132.51 h] |
| CO.0135 |  | Extracción de roca en cantera (con explosivos) Fase 1 | 25d | 2023-10-11 | 2023-11-09 | CO.0130, CO.0040, CO.0050 | 5d | 0d | CONSTRUCCION HH [3181.87 h]; EXTRACCIÓN DE ROCA [16269.8] |
| CO.0140 |  | Extracción de roca en cantera (con explosivos) Fase 2 | 25d | 2023-11-10 | 2023-12-11 | HUB.0020 FF, CO.0135, CO.0040, CO.0050 | 5d | 2d | CONSTRUCCION HH [3181.87 h]; EXTRACCIÓN DE ROCA [16269.8] |
|  | 1 | **SELECCIÓN DE ROCA** |  | 2023-10-11 | 2023-12-21 |  |  |  |  |
| CO.0150 |  | Selección y acopio de roca (de acuerdo al diseño y tipo) | 49d | 2023-10-11 | 2023-12-07 | CO.0130, CO.0040 | 28d | 0d | CONSTRUCCION HH [4780.06 h] |
| CO.0160 |  | Transporte de material interno para acopio =1km (incluye carguío) | 59d | 2023-10-11 | 2023-12-21 | CO.0150 SS | 28d | 0d | CONSTRUCCION HH [1187.69 h] |

| ID | WBS | Activity | Type | Duration | Start | Finish | Predecessors | Total float | Free float | Resources |
| --- | --- | --- | --- | --- | --- | --- | --- | --- | --- | --- |
|  | 2 | **ELIMINACIÓN DE ROCA (DESPERDICIO)** |  |  | 2023-10-11 | 2023-12-22 |  |  |  |  |
| CO.0180 |  | Eliminación de material excedente > 1km |  | 60d | 2023-10-11 | 2023-12-22 | CO.0160 SS | 28d | 0d | CONSTRUCCION HH [893.75 h] |
| CO.0170 |  | Eliminación de material excedente = 1km (incluye carguío) |  | 48d | 2023-10-24 | 2023-12-21 | CO.0160 FF, CO.0130, CO.0070 | 29d | 26d | CONSTRUCCION HH [1023.22 h] |
|  | 3 | **TRABAJOS DE CIERRE** |  |  | 2023-11-13 | 2023-12-23 |  |  |  |  |
| CO.0190 |  | Conformación de DME |  | 33d | 2023-11-13 | 2023-12-22 | CO.0180 FF, CO.0130, CO.0070 | 28d | 0d | CONSTRUCCION HH [390.47 h] |
| CO.0200 |  | Limpieza y nivelación del terreno |  | 1d | 2023-12-23 | 2023-12-23 | CO.0190, CO.0180, CO.0210 FF, CO.0220 FF, HUB.0010 FF | 94d |  | CONSTRUCCION HH [2.07 h] |
|  | 5 | **SEGURIDAD, SALUD Y MEDIO AMBIENTE** |  |  | 2023-05-17 | 2023-12-23 |  |  |  |  |
| CO.0210 |  | Mitigación de impacto ambiental | level of effort | 183d | 2023-05-17 | 2023-12-23 | CO.0010 SS | 94d | 0d | CONSTRUCCION HH [331.43 h] |
|  | 6 | **CONTROL DE TOPOGRAFÍA** |  |  | 2023-05-17 | 2023-12-23 |  |  |  |  |
| CO.0220 |  | Control topográfico de los trabajos | level of effort | 183d | 2023-05-17 | 2023-12-23 | CO.0010 SS | 94d | 0d | CONSTRUCCION HH [1325.73 h] |
|  | 6 | **QUEBRADA MALVAS** |  |  | 2023-08-07 | 2024-03-05 |  |  |  |  |
|  | 1 | **OBRAS PRELIMINARES** |  |  | 2023-08-07 | 2024-03-05 |  |  |  |  |
| QM.0010 |  | Movilización y desmovilización de maquinaria | level of effort | 176d | 2023-08-07 | 2024-03-05 | A2080 SS | 34d | 0d |  |
| QM.0020 |  | Ensayos de roca (determinado por el proveedor) | level of effort | 163d | 2023-08-16 | 2024-02-28 | A2090 SS | 34d | 0d |  |
|  | 3 | **ROCA 2** |  |  | 2023-08-07 | 2023-12-29 |  |  |  |  |
|  | 1 | **TRABAJOS DE CANTERA** |  |  | 2023-08-07 | 2023-12-28 |  |  |  |  |
| A2080 |  | Habilitación de caminos de accesos a Cantera |  | 8d | 2023-08-07 | 2023-08-15 | QA.0110 | 34d | 0d | CONSTRUCCION HH [721.27 h] |
| A2090 |  | Extracción de roca en cantera (con explosivos) Fase 1 |  | 44d | 2023-08-16 | 2023-10-06 | A2080 | 34d | 0d | CONSTRUCCION HH [11546 h]; EXTRACCIÓN DE ROCA [59038.1] |
| A2095 |  | Extracción de roca en cantera (con explosivos) Fase 2 |  | 44d | 2023-10-07 | 2023-11-28 | A2090 | 34d | 0d | CONSTRUCCION HH [11546 h]; EXTRACCIÓN DE ROCA [59038.1] |
| A2100 |  | Extracción de roca en cantera (con explosivos) Fase 3 |  | 23d | 2023-11-29 | 2023-12-28 | A2090, A2080, A2095 | 34d | 0d | CONSTRUCCION HH [11546 h]; EXTRACCIÓN DE ROCA [59038.1] |
|  | 2 | **SELECCIÓN DE ROCA** |  |  | 2023-09-02 | 2023-12-28 |  |  |  |  |
| QM.0060 |  | Selección y acopio de roca (de acuerdo al diseño y tipo) |  | 97d | 2023-09-02 | 2023-12-28 | A2090 SS+5d, A2100 FF, A2080 | 34d | 0d | CONSTRUCCION HH [26018.1 h] |
| QM.0070 |  | Transporte de material interno para acopio =1km (incluye carguío) |  | 80d | 2023-09-22 | 2023-12-28 | QM.0060 FF, A2080 | 34d | 0d | CONSTRUCCION HH [6464.67 h] |
|  | 3 | **ELIMINACIÓN DE ROCA (DESPERDICIO)** |  |  | 2023-09-20 | 2023-12-28 |  |  |  |  |
| QM.0090 |  | Eliminación de material excedente > 1km |  | 82d | 2023-09-20 | 2023-12-28 | QM.0060 FF, A2080 | 34d | 0d | CONSTRUCCION HH [4864.74 h] |
| QM.0080 |  | Eliminación de material excedente = 1km (incluye carguío) |  | 65d | 2023-10-10 | 2023-12-28 | QM.0060 FF, A2080 | 34d | 0d | CONSTRUCCION HH [5569.42 h] |

| ID | WBS | Activity | Type | Duration | Start | Finish | Predecessors | Total float | Free float | Resources |
| --- | --- | --- | --- | --- | --- | --- | --- | --- | --- | --- |
|  | 4 | **TRABAJO DE CIERRE** |  |  | 2023-10-07 | 2023-12-29 |  |  |  |  |
| QM.0100 |  | Conformación de DME |  | 67d | 2023-10-07 | 2023-12-28 | QM.0090 FF, A2080 | 34d | 0d | CONSTRUCCION HH [2125.37 h] |
| QM.0110 |  | Limpieza y nivelación del terreno |  | 1d | 2023-12-29 | 2023-12-29 | QM.0100, QM.0090, QM.0070, QM.0080, A2080 | 34d | 0d | CONSTRUCCION HH [11.29 h] |
|  | 4 | **CERRO MALVAS** |  |  | 2023-12-30 | 2024-03-05 |  |  |  |  |
|  | 1 | **TRABAJOS DE CANTERA** |  |  | 2023-12-30 | 2024-02-28 |  |  |  |  |
| QM.0120 |  | Habilitación de caminos de accesos a Cantera |  | 3d | 2023-12-30 | 2024-01-03 | QM.0110 | 34d | 0d | CONSTRUCCION HH [253.42 h] |
| QM.0130 |  | Extracción de roca en cantera (con explosivos) Fase 1 |  | 24d | 2024-01-04 | 2024-01-31 | QM.0120, A2090 | 34d | 0d | CONSTRUCCION HH [6085.08 h]; EXTRACCIÓN DE ROCA [31114.7] |
| QM.0220 |  | Extracción de roca en cantera (con explosivos) Fase 2 |  | 24d | 2024-02-01 | 2024-02-28 | QM.0130, QM.0020 FF, QM.0120 | 34d | 0d | CONSTRUCCION HH [6085.08 h]; EXTRACCIÓN DE ROCA [31114.7] |
|  | 2 | **SELECCIÓN DE ROCA** |  |  | 2024-01-08 | 2024-03-04 |  |  |  |  |
| QM.0140 |  | Selección y acopio de roca (de acuerdo al diseño y tipo) |  | 49d | 2024-01-08 | 2024-03-04 | QM.0220 FF+4d, QM.0120 | 34d | 0d | CONSTRUCCION HH [9141.49 h] |
| QM.0150 |  | Transporte de material interno para acopio =1km (incluye carguío) |  | 38d | 2024-01-20 | 2024-03-04 | QM.0140 FF, QM.0120 | 34d | 0d | CONSTRUCCION HH [2271.37 h] |
|  | 3 | **ELIMINACIÓN DE ROCA (DESPERDICIO)** |  |  | 2024-01-11 | 2024-03-04 |  |  |  |  |
| QM.0160 |  | Eliminación de material excedente = 1km (incluye carguío) |  | 46d | 2024-01-11 | 2024-03-04 | QM.0150 FF, QM.0120 | 34d | 0d | CONSTRUCCION HH [1956.82 h] |
| QM.0170 |  | Eliminación de material excedente > 1km |  | 39d | 2024-01-19 | 2024-03-04 | QM.0160 FF, QM.0120, QM.0100 | 34d | 0d | CONSTRUCCION HH [1709.23 h] |
|  | 4 | **TRABAJOS DE CIERRE** |  |  | 2024-01-10 | 2024-03-05 |  |  |  |  |
| QM.0180 |  | Conformación de DME |  | 47d | 2024-01-10 | 2024-03-04 | QM.0170 FF, QM.0120 | 34d | 0d | CONSTRUCCION HH [746.75 h] |
| QM.0190 |  | Limpieza y nivelación del terreno |  | 1d | 2024-03-05 | 2024-03-05 | QM.0180, QM.0200 FF, QM.0210 FF, QM.0010 FF, QM.0120, QM.0100 | 34d |  | CONSTRUCCION HH [3.97 h] |
|  | 5 | **SEGURIDAD, SALUD Y MEDIO AMBIENTE** |  |  | 2023-08-07 | 2024-03-05 |  |  |  |  |
| QM.0200 |  | Mitigación de impacto ambiental | level of effort | 176d | 2023-08-07 | 2024-03-05 | A2080 SS | 34d | 0d | CONSTRUCCION HH [877.62 h] |
|  | 6 | **CONTROL DE TOPOGRAFÍA** |  |  | 2023-08-07 | 2024-03-05 |  |  |  |  |
| QM.0210 |  | Control topográfico de los trabajos | level of effort | 176d | 2023-08-07 | 2024-03-05 | A2080 SS | 34d | 0d | CONSTRUCCION HH [3510.48 h] |
|  | 8 | **QUEBRADA AIJA** |  |  | 2023-05-18 | 2023-08-05 |  |  |  |  |
|  | 1 | **OBRAS PRELIMINARES** |  |  | 2023-05-18 | 2023-08-05 |  |  |  |  |
| QA.0010 |  | Movilización y desmovilización de maquinaria | level of effort | 66d | 2023-05-18 | 2023-08-05 | QA.0040 SS | 34d | 0d |  |
| QA.0020 |  | Ensayos de roca (determinado por el proveedor) | level of effort | 60d | 2023-05-24 | 2023-08-04 | QA.0050 SS | 34d | 0d |  |

| ID | WBS | Activity | Type | Duration | Start | Finish | Predecessors | Total float | Free float | Resources |
| --- | --- | --- | --- | --- | --- | --- | --- | --- | --- | --- |
|  | 3 | **CERRO AIJA** |  |  | 2023-05-18 | 2023-08-05 |  |  |  |  |
|  | 1 | **TRABAJOS DE CANTERA** |  |  | 2023-05-18 | 2023-07-21 |  |  |  |  |
| QA.0040 |  | Habilitación de caminos de accesos a Cantera |  | 5d | 2023-05-18 | 2023-05-23 | SD.0110 | 34d | 0d | CONSTRUCCION HH [262.94 h] |
| QA.0050 |  | Extracción de roca en cantera (con explosivos) Fase 1 |  | 25d | 2023-05-24 | 2023-06-21 | QA.0040 | 44d | 0d | CONSTRUCCION HH [6313.6 h]; EXTRACCIÓN DE ROCA [32283.2] |
| QA.0140 |  | Extracción de roca en cantera (con explosivos) Fase 2 |  | 25d | 2023-06-22 | 2023-07-21 | QA.0050, QA.0040 | 44d | 10d | CONSTRUCCION HH [6313.6 h]; EXTRACCIÓN DE ROCA [32283.2] |
|  | 2 | **SELECCIÓN DE ROCA** |  |  | 2023-05-24 | 2023-08-04 |  |  |  |  |
| QA.0060 |  | Selección y acopio de roca (de acuerdo al diseño y tipo) |  | 60d | 2023-05-24 | 2023-08-04 | QA.0020 FF, QA.0140 FF, QA.0040 | 34d | 0d | CONSTRUCCION HH [9484.8 h] |
| QA.0070 |  | Transporte de material interno para acopio =1km (incluye carguío) |  | 58d | 2023-05-26 | 2023-08-04 | QA.0060 SS+2d | 34d | 0d | CONSTRUCCION HH [2356.67 h] |
|  | 3 | **ELIMINACIÓN DE ROCA (DESPERDICIO)** |  |  | 2023-05-24 | 2023-08-04 |  |  |  |  |
| QA.0090 |  | Eliminación de material excedente > 1km |  | 60d | 2023-05-24 | 2023-08-04 | QA.0060 FF | 34d | 0d | CONSTRUCCION HH [1773.42 h] |
| QA.0080 |  | Eliminación de material excedente = 1km (incluye carguío) |  | 47d | 2023-06-08 | 2023-08-04 | QA.0070 FF, QA.0040 | 34d | 0d | CONSTRUCCION HH [2030.31 h] |
|  | 4 | **TRABAJO DE CIERRE** |  |  | 2023-06-07 | 2023-08-05 |  |  |  |  |
| QA.0100 |  | Conformación de DME |  | 48d | 2023-06-07 | 2023-08-04 | QA.0060 FF, QA.0040 | 34d | 0d | CONSTRUCCION HH [774.8 h] |
| QA.0110 |  | Limpieza y nivelación del terreno |  | 1d | 2023-08-05 | 2023-08-05 | QA.0100, QA.0090, QA.0120 FF, QA.0130 FF, QA.0080, QA.0010 FF, QA.0140 | 34d | 0d | CONSTRUCCION HH [4.12 h] |
|  | 4 | **SEGURIDAD, SALUD Y MEDIO AMBIENTE** |  |  | 2023-05-18 | 2023-08-05 |  |  |  |  |
| QA.0120 |  | Mitigación de impacto ambiental | level of effort | 66d | 2023-05-18 | 2023-08-05 | QA.0040 SS | 34d | 0d | CONSTRUCCION HH [236.75 h] |
|  | 5 | **CONTROL DE TOPOGRAFÍA** |  |  | 2023-05-18 | 2023-08-05 |  |  |  |  |
| QA.0130 |  | Control topográfico de los trabajos | level of effort | 66d | 2023-05-18 | 2023-08-05 | QA.0040 SS | 34d | 0d | CONSTRUCCION HH [947 h] |
|  | 9 | **SAN DAMIÁN** |  |  | 2023-01-25 | 2023-05-17 |  |  |  |  |
|  | 1 | **OBRAS PRELIMINARES** |  |  | 2023-01-25 | 2023-05-17 |  |  |  |  |
| SD.0010 |  | Movilización y desmovilización de maquinaria | level of effort | 94d | 2023-01-25 | 2023-05-17 | SD.0040 SS | 34d | 0d |  |
| SD.0020 |  | Ensayos de roca (determinado por el proveedor) | level of effort | 90d | 2023-01-28 | 2023-05-16 | SD.0050 SS | 34d | 0d |  |
|  | 3 | **ROCA IRMAN** |  |  | 2023-01-25 | 2023-05-17 |  |  |  |  |
|  | 1 | **TRABAJOS DE CANTERA** |  |  | 2023-01-25 | 2023-05-16 |  |  |  |  |
| SD.0040 |  | Habilitación de caminos de accesos a Cantera |  | 3d | 2023-01-25 | 2023-01-27 | HC.0050 SS | 5d | 0d | CONSTRUCCION HH [241.65 h] |
| SD.0050 |  | Extracción de roca en cantera (con explosivos) Fase 1 |  | 45d | 2023-01-28 | 2023-03-21 | SD.0040 | 5d | 0d | CONSTRUCCION HH [5802.38 h]; EXTRACCIÓN DE ROCA [29669.1] |
| SD.0140 |  | Extracción de roca en cantera (con explosivos) Fase 2 |  | 45d | 2023-03-22 | 2023-05-16 | SD.0050, SD.0020 FF, SD.0040 | 34d | 0d | CONSTRUCCION HH [5802.38 h]; EXTRACCIÓN DE ROCA [29669.1] |

| ID | WBS | Activity | Type | Duration | Start | Finish | Predecessors | Total float | Free float | Resources |
| --- | --- | --- | --- | --- | --- | --- | --- | --- | --- | --- |
|  | 2 | **SELECCIÓN DE ROCA** |  |  | 2023-01-28 | 2023-05-13 |  |  |  |  |
| SD.0060 |  | Selección y acopio de roca (de acuerdo al diseño y tipo) Fase 1 |  | 44d | 2023-01-28 | 2023-03-20 | SD.0040 | 36d | 0d | CONSTRUCCION HH [4358.4 h] |
| SD.0070 |  | Transporte de material interno para acopio =1km (incluye carguío) Fase 1 |  | 49d | 2023-01-28 | 2023-03-25 | SD.0040 | 51d | 0d | CONSTRUCCION HH [1082.92 h] |
| SD.0065 |  | Selección y acopio de roca (de acuerdo al diseño y tipo) Fase 2 |  | 44d | 2023-03-21 | 2023-05-13 | SD.0060 | 36d | 2d | CONSTRUCCION HH [4358.4 h] |
| SD.0075 |  | Transporte de material interno para acopio =1km (incluye carguío) Fase 2 |  | 24d | 2023-03-27 | 2023-04-25 | SD.0070 | 51d | 17d | CONSTRUCCION HH [1082.92 h] |
|  | 3 | **ELIMINACIÓN DE ROCA (DESPERDICIO)** |  |  | 2023-01-28 | 2023-05-11 |  |  |  |  |
| SD.0080 |  | Eliminación de material excedente = 1km (incluye carguío) Fase 1 |  | 43d | 2023-01-28 | 2023-03-18 | SD.0040 | 38d | 0d | CONSTRUCCION HH [932.96 h] |
| SD.0090 |  | Eliminación de material excedente > 1km Fase 1 |  | 51d | 2023-01-28 | 2023-03-28 | SD.0040 | 44d | 0d | CONSTRUCCION HH [814.91 h] |
| SD.0085 |  | Eliminación de material excedente = 1km (incluye carguío) Fase 2 |  | 43d | 2023-03-20 | 2023-05-11 | SD.0080 | 38d | 4d | CONSTRUCCION HH [932.96 h] |
| SD.0150 |  | Eliminación de material excedente > 1km Fase 2 |  | 25d | 2023-03-29 | 2023-04-28 | SD.0090 | 48d | 14d | CONSTRUCCION HH [814.91 h] |
|  | 4 | **TRABAJOS DE CIERRE** |  |  | 2023-03-22 | 2023-05-17 |  |  |  |  |
| SD.0100 |  | Conformación de DME |  | 45d | 2023-03-22 | 2023-05-16 | SD.0090 FF, SD.0050, SD.0040 | 5d | 0d | CONSTRUCCION HH [712.06 h] |
| SD.0110 |  | Limpieza y nivelación del terreno |  | 1d | 2023-05-17 | 2023-05-17 | SD.0100, SD.0090, SD.0120 FF, SD.0130 FF, SD.0010 FF, SD.0140, SD.0080, SD.0050, SD.0060, SD.0065, SD.0075, SD.0085, SD.0150 | 34d | 0d | CONSTRUCCION HH [3.78 h] |
|  | 4 | **SEGURIDAD, SALUD Y MEDIO AMBIENTE** |  |  | 2023-01-25 | 2023-05-17 |  |  |  |  |
| SD.0120 |  | Mitigación de impacto ambiental | level of effort | 94d | 2023-01-25 | 2023-05-17 | SD.0040 SS | 34d | 0d | CONSTRUCCION HH [217.58 h] |
|  | 5 | **CONTROL DE TOPOGRAFÍA** |  |  | 2023-01-25 | 2023-05-17 |  |  |  |  |
| SD.0130 |  | Control topográfico de los trabajos | level of effort | 94d | 2023-01-25 | 2023-05-17 | SD.0040 SS | 34d | 0d | CONSTRUCCION HH [870.32 h] |
|  | 7 | **OTROS** |  |  | 2022-10-11 | 2024-04-16 |  |  |  |  |
| VA.0040 |  | Examenes Médicos - Personal Directo (Ingreso y salida) |  | 58d | 2022-10-11 | 2022-12-20 | HT.0020 SS | 29d | 0d |  |
| VA.0010 |  | Transporte Interno - Personal Directo (Camioneta+chofer+combustible a doble turno) | level of effort | 428d | 2022-11-16 | 2024-04-16 | OP.0050 SS | 0d |  |  |
| VA.0070 |  | AGUA - Personal Directo (1lt/persona/dia=30lt/mes) | level of effort | 428d | 2022-11-16 | 2024-04-16 | OP.0050 SS | 0d |  |  |
| VA.0020 |  | EPPS - Personal Directo (renovacion cada 6 meses) |  | 15d | 2022-12-21 | 2023-01-06 | VA.0040 | 29d | 0d |  |
| VA.0050 |  | Certificado de Operadores - Personal Directo |  | 150d | 2023-01-07 | 2023-07-05 | VA.0020 | 29d |  |  |
| VA.0060 |  | Charla de Inducción - Personal Directo |  | 150d | 2023-01-07 | 2023-07-05 | VA.0040, VA.0020 | 29d |  |  |
| VA.0030 |  | EPPS - Personal Directo (renovacion cada 6 meses) |  | 15d | 2023-08-16 | 2023-09-02 | VA.0020 FS+183d, VA.0050, VA.0060 | 54d | 51d |  |
